# 3GPP_Release-2000

Schedule from MS Project, 2000-01-03 to 2008-07-11, A marks actual dates.

## Calendars

- Standard: Mon-Fri 08:00-12:00, 13:00-17:00; Sat-Sun off.

## Resources

| Resource |
| --- |
| NP |
| N1 |
| N2 |
| N3 |
| N4 |
| N5 |
| TP |
| T1 |
| T2 |
| T3 |
| RP |
| R1 |
| R2 |
| R3 |
| R4 |
| SP |
| S1 |
| S2 |
| S3 |
| S4 |
| S5 |
| PCG |
| GP |
| No |
| CN4 |
| ? |
| WG G2 |
| G2 |
| G1 |
| G4 |
| G3 |
| All |
| Generic |
| MLST |
| G5 |
| S3; G2 |
| WG T2 |
| GP;G1 |
| G4;G5 |
| OMA |
| GP-G2 |
| Yes |
| GP; |
| N4; |
| GP; N1 |
| CT5 |
| C5 |
| C1 |
| C4 |
| C3 |
| C6 |
| G1; |
| 4 |
| ct |
| c;s;r |
| CT;RAN;SA |
| G2; |
| G1; G3 |
| CT6 |

## Schedule

| ID | WBS | Task | Type | Duration | Start | Finish | Complete | Remaining | Baseline start | Baseline finish | Baseline duration | Total slack | Constraint | Resources | Work | Actual work | Text9 | Text6 | Text1 | Text4 | Text5 | Text7 | Text8 | Text12 |
| --- | --- | --- | --- | --- | --- | --- | --- | --- | --- | --- | --- | --- | --- | --- | --- | --- | --- | --- | --- | --- | --- | --- | --- | --- |
| 1 | 1 | VERSION 2006 October 13th |  | 1d | 2000-01-03 | 2000-01-03 |  |  | 2000-01-03 | 2000-01-03 | 1d | 2224d |  |  |  |  | 2044 |  |  |  |  |  |  |  |
| 2 | 2 | "CTRL + a" to display all the 3GPP fields |  | 1d | 2000-01-03 | 2000-01-03 |  |  | 2000-01-03 | 2000-01-03 | 1d | 2009d |  |  |  |  | 1462 |  |  |  |  |  |  |  |
| 3 | 3 | Content of Rel-7 and Rel-8 (not frozen) |  | 1d | 2000-01-03 | 2000-01-03 |  |  | 2000-01-03 | 2000-01-03 | 1d | 2224d |  |  |  |  | 2058 |  |  |  |  |  |  |  |
| 5 | 4 | Rel-7 Features |  | 1d? | 2000-01-03 | 2000-01-03 |  |  | 2000-01-03 | 2000-01-03 | 1d? | 2009d |  | CT;RAN;SA | 8h |  |  | Rel-7 |  |  |  |  |  |  |
| 6 | 8.5 | **Multiple Input Multiple Output antennas (MIMO)** |  | 1044d? | 2003-03-14 A | 2007-03-15 | 19% | 840.67d? | 2003-03-14 | 2006-06-15 | 850d? | 347d |  | R1 | 38120h | 7896.8h | 2468 | Rel-7 | MIMO | Howard Huang, Lucent | hchuang@lucent.com | TSG | Cesar |  |
| 7 | 5.1 | MIMO - Physical layer |  | 914d? | 2003-09-12 A | 2007-03-15 | 70% | 274.2d? | 2003-09-12 | 2006-06-15 | 720d? | 347d | finish no earlier than 2007-03-15 | R1 | 7312h | 5118.4h |  | Rel-7 | MIMO-Phys | Howard Huang, Lucent | hchuang@lucent.com | TSG | MCC_RAN |  |
| 8 | 5.2 | MIMO - Layer 2,3 aspects |  | 914d? | 2003-09-12 | 2007-03-15 |  |  | 2003-09-12 | 2006-06-15 | 720d? | 347d | finish no earlier than 2007-03-15 | R2 | 7312h |  |  | Rel-7 | MIMO-L23 | Howard Huang, Lucent | hchuang@lucent.com | TSG | MCC_RAN |  |
| 9 | 5.3 | MIMO - Iub/Iur Protocol Aspects |  | 1044d? | 2003-03-14 | 2007-03-15 |  |  | 2003-03-14 | 2006-06-15 | 850d? | 347d | finish no earlier than 2007-03-15 | R3 | 8352h |  |  | Rel-7 | MIMO-IurIub | Howard Huang, Lucent | hchuang@lucent.com | TSG | MCC_RAN |  |
| 10 | 5.4 | MIMO - RF Radio Transmission/Reception, System Performance Requirements and Conformance Testing |  | 849d? | 2003-12-12 A | 2007-03-15 | 10% | 764.1d? | 2003-12-12 | 2006-06-15 | 655d? | 347d | finish no earlier than 2007-03-15 | R4 | 6792h | 679.2h |  | Rel-7 | MIMO-RF | Man Hung Ng, Lucent | ngm@lucent.com | TSG | MCC_RAN |  |
| 11 | 6 | **Rel-7 Improvements of the Radio Interface** |  | 652d? | 2004-09-15 A | 2007-03-15 | 76% | 157.22d? | 2004-09-15 | 2006-12-15 | 588d? | 346d |  | RP | 30864h | 19914h |  | Rel-7 | RInImp |  |  |  | Cesar |  |
| 12 | 6.1 | Extended UMTS 1.7/2.1 GHz |  | 198d? | 2006-03-15 A | 2006-12-15 | 75% | 49.5d? | 2006-03-15 | 2006-12-15 | 198d? | 410d | finish no earlier than 2006-12-15 | R4 | 1584h | 1188h |  | Rel-7 | RInImp-UMTS1721Ext | Johan Sköld | johan.skold@ericsson.com |  | MCC_RAN |  |
| 13 | 6.2 | UMTS 2.6 GHz 7.68 MHz TDD |  | 67d? | 2006-06-15 A | 2006-09-15 A | 100% |  |  |  |  |  | finish no earlier than 2006-09-15 | R4 | 536h | 536h |  |  | RInImp-UMTS26VHCRTDD | Shin Horng Wong , IPWireless | shwong@ipwireless.com |  | MCC_RAN |  |
| 14 | 6.3 | UMTS 2.6 GHz |  | 195d? | 2004-09-15 A | 2005-06-14 A | 100% |  | 2004-09-15 | 2005-06-14 | 195d? |  | finish no earlier than 2005-06-14 | R4 | 1560h | 1560h |  | Rel-7 | RInImp-UMTS2600 | Jussi Numminen, Nokia | jussi.numminen@nokia.com | TSG | Cesar |  |
| 15 | 6.4 | UMTS 2.6 GHz TDD |  | 261d? | 2004-12-15 A | 2005-12-14 A | 100% |  | 2004-12-15 | 2005-12-14 | 261d? |  | finish no earlier than 2005-12-15 | R4 | 2088h | 2088h |  | Rel-7 | RInImp-UMTS2600TDD | Shin Horng Wong (IPWireless) | shwong@IPWIRELESS.COM | TSG | MCC_RAN |  |
| 16 | 6.5 | UMTS 900 MHz |  | 261d? | 2004-12-15 A | 2005-12-14 A | 100% |  | 2004-12-15 | 2005-12-14 | 261d? |  | finish no earlier than 2005-12-15 | R4 | 2088h | 2088h |  | Rel-7 | RInImp-UMTS900 | Yannick Li (Nortel) | yli@nortelnetworks.com | TSG | MCC_RAN |  |
| 17 | 6.6 | UMTS 1700 MHz |  | 197d? | 2005-03-15 A | 2005-12-14 A | 100% |  | 2005-03-15 | 2005-12-14 | 197d? |  | finish no earlier than 2005-12-15 | R4 | 1576h | 1576h |  | Rel-7 | RInImp-UMTS1700 | Takehiro Nakamura | NTT DoCoMo | TSG | MCC_RAN |  |
| 18 | 6.7 | UE Antenna Performance Evaluation Method and Requirements |  | 523d? | 2004-12-15 A | 2006-12-15 | 80% | 104.6d? | 2004-12-15 | 2006-06-15 | 392d? | 410d | finish no earlier than 2006-12-15 | R4 | 4184h | 3347.2h |  | Rel-7 | RInImp-UEAnt | Christian Bergljung (TeliaSonera) | Christian.Bergljung@TeliaSonera.com | TSG | MCC_RAN |  |
| 19 | 6.8 | Improved Performance Requirements for HSDPA UE based on Rx Diversity (type 1) & LMMSE equalizer (type 2) | milestone | 0d? | 2005-03-15 A | 2005-03-15 A | 100% |  | 2005-03-15 | 2005-03-15 | 0d? |  | finish no earlier than 2005-03-15 | R4 |  |  |  | Rel-7 | RInImp-HSPerf-Type3 | Marc Grant | marc.grant@cingular.com | TSG | MCC_RAN |  |
| 20 | 6.9 | **Additional minimum UE performance requirement for non-HSDPA channels based on type 1 enhanced receiver (Rx Diversity)** |  | 391d? | 2005-09-15 A | 2007-03-15 | 64% | 142.48d? | 2005-09-15 | 2006-06-15 | 195d? | 346d |  | R4 | 8880h | 4428.08h |  | Rel-7 | RInImp-RxDiv | Serge Willenegger | sergew@qualcomm.com |  | MCC_RAN |  |
| 21 | 6.9.1 | Additional minimum UE performance requirement for DL physical channels in support of DCH/HS-DSCH operation based on type 1 enhanced receiver (RX-Diversity) |  | 195d? | 2005-09-15 A | 2006-06-14 A | 100% |  | 2005-09-15 | 2006-06-15 | 195d? |  | finish no earlier than 2006-06-15 | R4 | 1560h | 1560h |  | Rel-7 | RInImp-RxDiv-DCH | Marc Grant | marc.grant@cingular.com | TSG | MCC_RAN |  |
| 22 | 6.9.2 | Additional minimum UE performance requirement for downlink physical channels in support of MTCH and MCCH operation based on type 1 enhanced receiver (Rx-Diversity) |  | 262d? | 2006-03-15 A | 2007-03-15 | 50% | 131d? | 2006-03-15 | 2006-03-15 | 1d? | 346d | finish no earlier than 2007-03-15 | R4 | 2096h | 1048h |  | Rel-7 | RInImp-RxDiv-MBMS | Serge Willenegger | sergew@qualcomm.com |  | MCC_RAN |  |
| 23 | 6.9.3 | Additional minimum UE performance requirement for downlink physical channels in support of E-DCH operation based on type 1 enhanced receiver (Rx-Diversity) |  | 262d? | 2006-03-15 A | 2007-03-15 | 50% | 131d? | 2006-03-15 | 2006-03-15 | 1d? | 346d | finish no earlier than 2007-03-15 | R4 | 2096h | 1048h |  | Rel-7 | RInImp-RxDiv-EDCH | Serge Willenegger | sergew@qualcomm.com |  | MCC_RAN |  |
| 24 | 6.10 | Improved support of gaming over HSDPA/EDCH |  | 262d? | 2005-12-15 A | 2006-12-15 | 35% | 170.3d? | 2005-12-15 | 2006-12-15 | 262d? | 410d | finish no earlier than 2006-12-15 | R2 | 2096h | 733.6h |  | Rel-7 | RInImp-Gaming | Don Zelmer, Cingular | don.zelmer@cingular.com |  | MCC_RAN |  |
| 25 | 6.11 | Interface to control Tower Mounted Amplifiers (TMAs) |  | 132d? | 2006-06-15 A | 2006-12-15 | 30% | 92.4d? |  |  |  | 410d | finish no earlier than 2006-12-15 | R3 | 1056h | 316.8h |  | Rel-7 | RInImp-TMA | Alexej Kulakov, Vodafone |  |  | MCC_RAN |  |
| 26 | 6.12 | Deleted (not approved at PCG) - UMTS 2.6 GHz FDD DL External | milestone | 0d? | 2005-09-15 A | 2005-09-15 A | 100% |  | 2005-09-15 | 2005-09-15 | 0d? |  | finish no earlier than 2005-09-15 | R4 |  |  |  | Rel-7 | RInImp-UMTS2600Ext | Han van Bussel | han.van.bussel@t-mobile.de | TSG | MCC_RAN | RP-31 |

Notes:
- 6: Text3: TR25.876,TR25.996
- 7: Text3: 25.211, 25.212, 25.213, 25.214, 25.215, 25.221, 25
- 8: Text3: TR 25.876
- 12: Text3: 25.806, 25.101, 25.104, 25.133, 24.141, 25.331, 25.306, 25.307, 25.423, 25.461, 25.463, 34.121
- 13: Approved at RP#33 as RP-060451 / Text3: 25.102, 25.105, 25.123, 25.113, 25.142, 34.124
- 14: Approved at RP#25 as RP-040377 / Text3: TS25.101, TS25.104, TS25.133, TS25.141, TS25.331, TS25.942, TS25.306, TS25.307, TS34.121
- 15: Text3: 25.102, 25.105, 25.113, 25.123, 25.142, 25.331, 25.942, 25.306, 25.307, 34.122, 34.124
- 16: Text3: 25.101, 25.104, 25.113, 25.133, 25.141, 25.331, 25.942, 25.306, 25.307, 34.121
- 17: Text3: 25.101, 25.104, 25.113, 25.133, 25.141, 25.306, 25.307, 25.331, 34.121
- 18: Text3: TS25.101
- 19: Text3: 25.101
- 21: Text3: 25.101
- 22: Text3: 25.101
- 23: Text3: 25.101
- 26: This item was conditionnaly approved pending decision of PCG 16 who decided not to approve it / Text3: 25.101, 25.104, 25.133, 25.141, 25.331, 25.942, 25.306, 25.307, 34.121

| ID | WBS | Task | Duration | Start | Finish | Complete | Remaining | Baseline start | Baseline finish | Baseline duration | Total slack | Constraint | Resources | Work | Actual work | Text1 | Text4 | Text5 | Text6 | Text7 | Text8 |
| --- | --- | --- | --- | --- | --- | --- | --- | --- | --- | --- | --- | --- | --- | --- | --- | --- | --- | --- | --- | --- | --- |
| 27 | 7 | **7.68Mcps TDD option** | 457d? | 2004-09-15 A | 2006-06-15 A | 100% |  | 2004-09-15 | 2006-06-15 | 457d? |  |  | RP | 19824h | 19824h | VHCRTDD | Martin Beale, IPWireless | mbeale@ipwireless.com | Rel-7 | TSG | Cesar |
| 28 | 7.1 | VHCRTDD: Stage 2 | 391d? | 2004-09-15 A | 2006-03-15 A | 100% |  | 2004-09-15 | 2006-03-15 | 391d? |  | finish no earlier than 2006-03-15 | R1 | 3128h | 3128h | VHCRTDD-Stage2 | Martin Beale, IPWireless | mbeale@ipwireless.com | Rel-7 | TSG | MCC_RAN |
| 29 | 7.2 | VHCRTDD: Physical Layer | 391d? | 2004-09-15 A | 2006-03-15 A | 100% |  | 2004-09-15 | 2006-03-15 | 391d? |  | finish no earlier than 2006-03-15 | R1 | 3128h | 3128h | VHCRTDD-Phys | Martin Beale, IPWireless | mbeale@ipwireless.com | Rel-7 | TSG | MCC_RAN |
| 30 | 7.3 | VHCRTDD: Layer 2 and layer 3 protocol aspects | 391d? | 2004-09-15 A | 2006-03-15 A | 100% |  | 2004-09-15 | 2006-03-15 | 391d? |  | finish no earlier than 2006-03-15 | R2 | 3128h | 3128h | VHCRTDD-L23 | Derek Richards, IPWireless | drichards@ipwireless.com | Rel-7 | TSG | MCC_RAN |
| 31 | 7.4 | VHCRTDD: UTRAN Iub/Iur Protocol Aspects | 391d? | 2004-09-15 A | 2006-03-15 A | 100% |  | 2004-09-15 | 2006-03-15 | 391d? |  | finish no earlier than 2006-03-15 | R3 | 3128h | 3128h | VHCRTDD-IurIub | Peter Legg, IPWireless | plegg@ipwireless.com | Rel-7 | TSG | MCC_RAN |
| 32 | 7.5 | VHCRTDD: RF Radio Transmission/ Reception, System Performance Requirements and Conformance Testing | 457d? | 2004-09-15 A | 2006-06-15 A | 100% |  | 2004-09-15 | 2006-06-15 | 457d? |  | finish no earlier than 2006-06-15 | R4 | 3656h | 3656h | VHCRTDD-RF | Shin Horng Wong | shwong@ipwireless.com | Rel-7 | TSG | MCC_RAN |
| 33 | 8 | **Rel-7 RAN improvements** | 523d? | 2004-12-15 A | 2006-12-15 | 91% | 45.59d? | 2004-12-15 | 2006-12-15 | 523d? | 410d |  | RP | 20992h | 16035.3h | RANimp |  |  | Rel-7 | TSG | MCC_RAN |
| 34 | 8.1 | Optimisation of channelisation code utilisation for 1.28 Mcps TDD | 523d? | 2004-12-15 A | 2006-12-15 | 90% | 52.3d? | 2004-12-15 | 2006-06-15 | 392d? | 410d | finish no earlier than 2006-12-15 | R1 | 4184h | 3765.6h | RANimp-RABSE-CodOptLCRTDD | Ka Leong Lo | kaleong.lo@utstar.com | Rel-7 | TSG | MCC_RAN |
| 35 | 8.2 | Delay optimisation for procedures applicable to CS and PS Connections | 394d? | 2005-03-15 A | 2006-09-15 A | 100% |  | 2005-03-15 | 2006-09-15 | 394d? |  | finish no earlier than 2006-09-15 | R2 | 3152h | 3152h | RANimp-DelayOpt | Juho Pirskanen | juho.pirskanen@nokia.com | Rel-7 | TSG | MCC_RAN |
| 36 | 8.3 | UE Performance Requirements for MBMS (TDD) | 328d? | 2005-03-15 A | 2006-06-15 A | 100% |  | 2005-03-15 | 2006-06-15 | 328d? |  | finish no earlier than 2006-06-15 | R4 | 2624h | 2624h | MBMS-RAN-RF-TDD | Shin Horng Wong | shwong@ipwireless.com | Rel-7 | TSG | MCC_RAN |
| 37 | 8.4 | Continuous connectivity for packet data users | 460d? | 2005-03-14 A | 2006-12-15 | 75% | 115d? | 2005-03-14 | 2005-09-15 | 134d? | 410d | finish no earlier than 2006-12-15 | R1 | 3680h | 2760h | RANimp-CPC | Joern Krause | Joern.Krause@siemens.com | Rel-7 | TSG | MCC_RAN |
| 38 | 8.5 | Extended WCDMA Cell Range | 198d? | 2006-03-15 A | 2006-12-15 | 97% | 5.94d? | 2006-03-15 | 2006-09-15 | 133d? | 410d | finish no earlier than 2006-12-15 | R3 | 1584h | 1536.48h | RANimp-ExtCell | Ericsson |  | Rel-7 |  | MCC_RAN |
| 39 | 8.6 | 7.68 Mcps TDD Enhanced Uplink | 198d? | 2006-03-15 A | 2006-12-15 | 95% | 9.9d? | 2006-03-15 | 2006-12-15 | 198d? | 410d | finish no earlier than 2006-12-15 | R1 | 1584h | 1504.8h | RANimp-VHCRTDD-EDCH | Nicholas Anderson | nanderson@ipwireless.com | Rel-7 |  | MCC_RAN |
| 40 | 9 | **3.84 Mcps TDD Enhanced Uplink** | 394d? | 2005-03-15 A | 2006-09-15 A | 100% |  | 2005-03-15 | 2006-09-15 | 394d? |  |  | RP | 18384h | 18384h | EDCHTDD | Nicholas Anderson | nanderson@ipwireless.com | Rel-7 | TSG | MCC_RAN |
| 41 | 9.1 | EDCHTDD: Stage 2 | 328d? | 2005-03-15 A | 2006-06-15 A | 100% |  | 2005-03-15 | 2006-06-15 | 328d? |  | finish no earlier than 2006-06-15 | R2 | 2624h | 2624h | EDCHTDD-Stage2 | Nicholas Anderson | nanderson@ipwireless.com | Rel-7 | TSG | MCC_RAN |
| 42 | 9.2 | EDCHTDD: Physical Layer | 394d? | 2005-03-15 A | 2006-09-15 A | 100% |  | 2005-03-15 | 2006-06-15 | 328d? |  | finish no earlier than 2006-09-15 | R1 | 3152h | 3152h | EDCHTDD-Phys | Nicholas Anderson | nanderson@ipwireless.com | Rel-7 | TSG | MCC_RAN |
| 43 | 9.3 | EDCHTDD: Layer 2 and 3 Protocol Aspects | 394d? | 2005-03-15 A | 2006-09-15 A | 100% |  | 2005-03-15 | 2006-06-15 | 328d? |  | finish no earlier than 2006-09-15 | R2 | 3152h | 3152h | EDCHTDD-L23 | Derek Richards | drichards@ipwireless.com | Rel-7 | TSG | MCC_RAN |
| 44 | 9.4 | EDCHTDD: UTRAN Iub/Iur Protocol Aspects | 394d? | 2005-03-15 A | 2006-09-15 A | 100% |  | 2005-03-15 | 2006-09-15 | 394d? |  | finish no earlier than 2006-09-15 | R3 | 3152h | 3152h | EDCHTDD-IurIub | Jim Miller | jim.miller@interdigital.com | Rel-7 | TSG | MCC_RAN |
| 45 | 9.5 | EDCHTDD: RF Radio Transmission/ Reception, System Performance Requirements and Conformance Testing | 394d? | 2005-03-15 A | 2006-09-15 A | 100% |  | 2005-03-15 | 2006-09-15 | 394d? |  | finish no earlier than 2006-09-15 | R4 | 3152h | 3152h | EDCHTDD-RF | Shin Horng Wong | shwong@ipwireless.com | Rel-7 | TSG | MCC_RAN |
| 46 | 10 | **1.28 Mcps TDD Enhanced Uplink** | 262d? | 2006-03-15 A | 2007-03-15 | 30% | 183.22d? | 2006-03-15 | 2007-03-15 | 262d? | 346d |  | RP | 8944h | 2689.47h | LCRTDD-EDCH | Haijing Hu (CATT) |  | Rel-7 |  | MCC_RAN |
| 47 | 10.1 | 1.28 Mcps TDD Enhanced Uplink: Physical Layer | 198d? | 2006-03-15 A | 2006-12-15 | 40% | 118.8d? | 2006-03-15 | 2006-12-15 | 198d? | 410d | finish no earlier than 2006-12-15 | R1 | 1584h | 633.6h | LCRTDD-EDCH-Phys | Ke Wang (CATT) |  | Rel-7 |  | MCC_RAN |
| 48 | 10.2 | 1.28 Mcps TDD Enhanced Uplink: Layer 2 and 3 Protocol Aspects | 198d? | 2006-03-15 A | 2006-12-15 | 80% | 39.6d? | 2006-03-15 | 2006-12-15 | 198d? | 410d | finish no earlier than 2006-12-15 | R2 | 1584h | 1267.2h | LCRTDD-EDCH-L23 | Haiyang Quan (CATT) |  | Rel-7 |  | MCC_RAN |
| 49 | 10.3 | 1.28 Mcps TDD Enhanced Uplink: UTRAN Iub/Iur Protocol Aspects | 198d? | 2006-03-15 A | 2006-12-15 | 10% | 178.2d? | 2006-03-15 | 2006-12-15 | 198d? | 410d | finish no earlier than 2006-12-15 | R3 | 1584h | 158.4h | LCRTDD-EDCH-IubIur | Yincheng Zhang (CATT) |  | Rel-7 |  | MCC_RAN |
| 50 | 10.4 | 1.28 Mcps TDD Enhanced Uplink: RF Radio Transmission/ Reception, System Performance Requirements and Conformance Testing | 262d? | 2006-03-15 | 2007-03-15 |  |  | 2006-03-15 | 2007-03-15 | 262d? | 346d | finish no earlier than 2007-03-15 | R4 | 2096h |  | LCRTDD-EDCH-RF | Yuexia Song (CATT) |  | Rel-7 |  | MCC_RAN |

Notes:
- 27: Approved at RP#25 as RP-040365
- 28: Feature completed and closed at RP#33 with the presentation of the test WI / Text3: TS25.202
- 29: Feature completed and closed at RP#33 with the presentation of the test WI / Text3: TS25.221, TS25.222, TS25.223, TS25.224,TS25.225
- 30: Feature completed and closed at RP#33 with the presentation of the test WI / Text3: TS25.301, TS25.302, TS25.305, TS25.306, TS25.321, TS25.331
- 31: Feature completed and closed at RP#33 with the presentation of the test WI / Text3: TS25.401, TS25.420, TS25.423, TS25.425, TS25.427, TS25.430, TS25.433, TS25.435
- 32: Feature completed and closed at RP#33 with the presentation of the test WI / Text3: TS25.102, TS25.105, TS25.123, TS25.133, TS25.142
- 33: Generic feature
- 35: Approved at RP#33 as RP-060453 / Text3: TS25.321, TS25.322, TS25.331
- 36: WI completed and closed with the presentation of the test WI / Text3: TS25.102, TS25.123
- 38: Text3: 25.133, 25.423, 25.425, 25.433, 25.435, 25.453, 25.331
- 39: Text3: 25.201, 25.202, 25.221, 25.222, 25.223, 25.224, 25.225, 25.331, 23.321, 25.306, 25.302, 25.401, 25.420, 25.423, 25.427, 25.433, 25.102, 25.105, 25.142
- 40: Approved at RP#33 as RP-060462
- 42: Text3: TS25.201, TS25.221,TS25.222, TS25.223, TS25.224, TS25.225
- 43: Text3: TS25.301, TS25.302, TS25.306, TS25.321, TS25.331
- 44: Text3: TS25.401, TS25.420, TS25.423, TS25.427, TS25.430, TS25.433, TS25.435
- 45: Text3: TS25.102, TS25.105, TS25.123, TS25.142
- 47: Text3: 25.201, 25.221, 25.222, 25.223, 25.224, 25.225
- 48: Text3: 25.301, 25.302, 25.306, 25.321, 25.331
- 49: Text3: 25.401, 25.420, 25.423, 25.425, 25.427, 25.430, 25.433, 25.435
- 50: Text3: 25.102, 25.105, 25.123, 25.142

| ID | WBS | Task | Type | Duration | Start | Finish | Complete | Remaining | Baseline start | Baseline finish | Baseline duration | Total slack | Constraint | Resources | Work | Actual work | Text1 | Text4 | Text6 | Text7 | Text8 | Text2 | Text3 | Text9 | Text5 | Text12 |
| --- | --- | --- | --- | --- | --- | --- | --- | --- | --- | --- | --- | --- | --- | --- | --- | --- | --- | --- | --- | --- | --- | --- | --- | --- | --- | --- |
| 51 | 11 | **PS domain and IMS impacts for supporting IMS Emergency calls** |  | 1694d? | 2000-09-18 A | 2007-03-15 | 75% | 431.06d? | 2000-09-18 | 2006-09-15 | 1565d? | 346d |  | S2 | 43325h | 31020.5h | EMC1 | Rainer Liebhart | Rel-7 | TSG | Maurice |  |  |  |  |  |
| 52 | 10.1.1 | Service Requirements for IP-based emergency calls |  | 985d | 2000-09-18 A | 2004-06-25 A | 100% |  | 2000-09-18 | 2004-06-25 | 985d |  | finish no earlier than 2004-06-25 | S1 | 7880h | 7880h |  |  | Rel-7 |  |  | CCaR | 22.976 | 1314 |  |  |
| 53 | 11.2 | Study on Stage 2 for IMS-level solution |  | 668d? | 2003-02-26 A | 2005-09-16 A | 100% |  | 2003-02-26 | 2005-09-16 | 668d? |  | finish no earlier than 2005-09-16 | S2 | 5344h | 5344h |  | Rainer Liebhart, Siemenws | Rel-7 | TSG |  |  | 23.228, 23.060, 23.002 |  |  |  |
| 54 | 11.3 | Study on Stage 2 for GPRS-level solution |  | 301d? | 2004-10-14 A | 2005-12-08 A | 100% |  | 2004-10-14 | 2005-12-08 | 301d? |  | finish no earlier than 2005-12-08 | S2 | 2408h | 2408h |  |  | Rel-7 |  |  |  |  |  |  |  |
| 55 | 11.4 | Stage 2 Specification Phase - IMS-level |  | 200d? | 2005-09-05 A | 2006-06-09 A | 100% |  | 2005-09-05 | 2006-06-09 | 200d? |  | finish no earlier than 2006-06-09 | S2 | 1600h | 1600h |  |  | Rel-7 |  |  |  |  |  |  |  |
| 56 | 11.5 | Stage 2 Specification Phase - GPRS-level |  | 345d? | 2005-09-05 A | 2006-12-29 | 69% | 106.95d? | 2005-09-05 | 2006-09-15 | 270d? | 400d | finish no earlier than 2006-12-29 | S2 | 2760h | 1904.4h |  |  | Rel-7 |  |  |  |  |  |  |  |
| 57 | 10.1 | **Emergency Call Enhancements for IP& PS Based Calls – stage 3** |  | 309d | 2006-01-09 A | 2007-03-15 | 18% | 252.75d | 2006-01-09 | 2006-09-15 | 180d | 346d |  | C1 | 9780.96h | 1780.6h | EMC1 | Alf Heidermark (Ericsson) | Rel-7 |  |  | CCaR |  | 1653 | alf.heidermark@ericsson.com |  |
| 58 | 10.1.2 | CT1 IMS aspects to support IMS Emergency sessions |  | 284.82d | 2006-01-09 A | 2007-03-15 | 60% | 113.93d | 2006-01-09 | 2006-09-15 | 155.82d | 346d | finish no earlier than 2007-03-15 | C1 | 2278.56h | 1367.13h |  | Alf Heidermark (Ericsson) | Rel-7 |  |  | CCaR | 24.229 | 1315 | alf.heidermark@ericsson.com |  |
| 59 | 10.1.2 | CT3 IMS aspects to support IMS Emergency sessions |  | 95d | 2006-05-08 | 2006-09-15 |  |  | 2006-05-08 | 2006-09-15 | 95d | 475d | finish no earlier than 2006-09-15 | C3 | 760h |  |  | Alf Heidermark (Ericsson) | Rel-7 |  |  | CCaR | 29.163 | 1315 | alf.heidermark@ericsson.com |  |
| 60 | 10.1.5 | CT1 PS domain aspects to support IMS Emergency sessions |  | 283.9d | 2006-01-09 | 2007-03-15 |  |  | 2006-01-09 | 2006-09-15 | 154.9d | 346d | finish no earlier than 2007-03-15 | C1 | 2271.2h |  |  | Alf Heidermark (Ericsson) | Rel-7 |  |  | CCaR | 24.008 | 1646 | alf.heidermark@ericsson.com |  |
| 61 | 10.1.5 | CT3 PS domain aspects to support IMS Emergency sessions |  | 95d | 2006-05-08 | 2006-09-15 |  |  | 2006-05-08 | 2006-09-15 | 95d | 475d | start no earlier than 2006-05-08 | C3 | 760h |  |  | Alf Heidermark (Ericsson) | Rel-7 |  |  | CCaR | 29.061 | 1646 | alf.heidermark@ericsson.com |  |
| 62 | 10.1.5 | CT4 PS domain aspects to support IMS Emergency sessions |  | 180d | 2006-01-09 | 2006-09-15 |  |  | 2006-01-09 | 2006-09-15 | 180d | 475d | start no earlier than 2006-01-09 | C4 | 1440h |  |  | Alf Heidermark (Ericsson) | Rel-7 |  |  | CCaR | 29.060 | 1646 | alf.heidermark@ericsson.com |  |
| 63 | 12 | **Access Class Barring and Overload Protection** |  | 650d? | 2004-03-15 A | 2006-09-08 A | 100% |  | 2004-03-15 | 2006-01-31 | 492d? |  |  | S2 | 8768h | 8768h | ACBOP | Chris Pudney, Vodafone | Rel-7 | TSG | Maurice |  | 23.898 |  |  |  |
| 64 | 12.1 | TR on Stage 2 |  | 274d? | 2004-03-15 A | 2005-03-31 A | 100% |  | 2004-03-15 | 2005-03-31 | 274d? |  | finish no earlier than 2005-03-31 | S2 | 2192h | 2192h |  |  | Rel-7 | TSG |  |  |  |  |  |  |
| 65 | 12.2 | Stage 3 CN aspects of ACBOP |  | 172d? | 2005-06-06 A | 2006-01-31 A | 100% |  | 2005-06-06 | 2006-01-31 | 172d? |  | start no earlier than 2005-06-06 | C1 | 1376h | 1376h |  |  | Rel-7 |  |  |  | 24.008 |  |  |  |
| 66 | 12.3 | Deleted - Potential impact on Iu interface Overload functionality | milestone | 0d? | 2004-03-15 A | 2004-03-15 A | 100% |  | 2004-03-15 | 2004-03-15 | 0d? |  | finish no earlier than 2004-03-15 | RP |  |  |  |  | Rel-7 |  |  |  | 25.413 |  |  | RP-25 |
| 67 | 12.4 | Deleted - Extra ACBOP information in RAN | milestone | 0d? | 2004-03-15 A | 2004-03-15 A | 100% |  | 2004-03-15 | 2004-03-15 | 0d? |  | finish no earlier than 2004-03-15 | RP |  |  |  |  | Rel-7 |  |  |  | 25.331 |  |  | RP-25 |
| 68 | 12.5 | Deleted - Extra ACBOP information in GERAN | milestone | 0d? | 2006-09-08 A | 2006-09-08 A | 100% |  | 2004-03-15 | 2005-11-18 | 440d? |  | start no earlier than 2006-09-08 | GP |  |  |  |  | Rel-7 | TSG | Gert |  | 44.018 |  |  |  |
| 69 | 13 | **USSD message delivery and transfer to USIM** |  | 376d? | 2004-03-05 A | 2005-08-12 A | 100% |  | 2004-03-05 | 2005-08-12 | 376d? |  |  | S1 | 5698.4h | 5698.4h | USSD-USIM |  | Rel-7 | TSG | Michael |  | 22.090 |  |  |  |
| 70 | 13.1 | Stage 1 |  | 152d? | 2004-03-18 A | 2004-10-15 A | 100% |  | 2004-03-18 | 2004-10-15 | 152d? |  | start no earlier than 2004-03-18 | S1 | 1216h | 1216h | USSD-USIM |  | Rel-7 | TSG | Michael |  | 22.090 |  |  |  |
| 71 | 13.2 | Alignment with requirements regarding USSD usage |  | 193.3d? | 2004-03-05 A | 2005-08-12 A | 100% |  | 2004-03-05 | 2005-08-12 | 193.3d? |  | finish no earlier than 2005-08-12 | C6 | 1546.4h | 1546.4h | USSD-USIM | Christophe Dubois (Axalto) | Rel-7 | TSG |  |  |  |  | cdubois@axalto.com |  |
| 72 | 14 | **Location Services enhancements Rel-7** |  | 709d? | 2004-06-28 A | 2007-03-15 | 90% | 70.1d? | 2004-06-28 | 2006-09-15 | 580d? | 346d |  | S2 | 36405.6h | 26301.2h | LCS3 |  | Rel-7 |  | Maurice |  | 23.271 |  |  |  |
| 73 | 14.1 | Global Stage 2 for LCS3 (including IMS emergency location aspects) |  | 446d? | 2004-12-31 A | 2006-09-15 A | 100% |  | 2004-12-31 | 2006-09-15 | 446d? |  | finish no earlier than 2006-09-15 | S2 | 3568h | 3568h |  | Ben Rodilitz, SiRF | Rel-7 | TSG | Maurice |  | 23.271 |  | brodilitz@sirf.com |  |
| 74 | 14.2 | CT4 aspects for LCS |  | 66d? | 2006-01-02 A | 2006-04-03 | 60% | 26.4d? | 2006-01-02 | 2006-04-03 | 66d? | 594d | start no earlier than 2006-01-01 | C4 | 528h | 316.8h | LCS3-UEPos-LBS |  | Rel-7 | TSG |  |  |  |  |  |  |

Notes:
- 60: end date updated by CT1-chairman after CT#33
- 65: NEW - inserted on 2/9/2004
- 73: Approved SA#27. Appropriate place forEmergency work to be found
- 74: CR approved in CT4#30

| ID | WBS | Task | Type | Duration | Start | Finish | Complete | Remaining | Baseline start | Baseline finish | Baseline duration | Total slack | Constraint | Resources | Work | Actual work | Text1 | Text6 | Text7 | Text8 | Text5 | Text12 |
| --- | --- | --- | --- | --- | --- | --- | --- | --- | --- | --- | --- | --- | --- | --- | --- | --- | --- | --- | --- | --- | --- | --- |
| 75 | 14.3 | **LCS for 3GPP Interworking WLAN** |  | 640d? | 2004-06-28 A | 2006-12-08 | 96% | 24.28d? | 2004-06-28 | 2006-09-15 | 580d? | 415d |  | S1 | 10181.6h | 4968h | LCS3-IWLAN | Rel-7 | TSG | Michael |  |  |
| 76 | 14.3.1 | FS on 3GPP system to WLAN Interworking with LCS |  | 512.7d? | 2004-06-28 A | 2006-06-30 A | 100% |  | 2004-06-28 | 2006-06-30 | 512.7d? |  | finish no earlier than 2005-09-29 | S1 | 4101.6h | 4101.6h |  | Rel-7 |  |  |  |  |
| 77 | 14.3.2 | Study of work on an LCS architecture for I-WLAN. |  | 120d? | 2006-06-26 A | 2006-12-08 | 80% | 24d? | 2006-01-16 | 2006-09-15 | 175d? | 415d | start no earlier than 2006-06-26 | S2 | 960h | 768h |  | Rel-7 |  | Maurice | dhshim@lge.com ; phede@lge.com |  |
| 78 | 14.4 | **UE positioning Rel-7** |  | 652d? | 2004-09-15 A | 2007-03-15 | 77% | 152.2d? | 2004-09-15 | 2006-06-15 | 456d? | 346d |  | RP | 10432h | 6709.24h | LCS3-UEpos | Rel-7 | TSG | Cesar |  |  |
| 79 | 14.4.1 | Inclusion of Uplink TDOA UE positioning method in the UTRAN specifications |  | 652d? | 2004-09-15 A | 2007-03-15 | 77% | 152.2d? | 2004-09-15 | 2006-06-15 | 456d? | 346d | finish no earlier than 2007-03-15 | R2 | 5216h | 3998.4h | LCS3-UEPos-UTDOA | Rel-7 | TSG | MCC_RAN | rlgross@trueposition.com |  |
| 80 | 14.5 | UE positioning - Velocity |  | 198d? | 2005-03-15 A | 2005-12-15 | 75% | 49.5d? | 2005-03-15 | 2005-06-14 | 66d? | 671d | finish no earlier than 2005-12-15 | R2 | 1584h | 1188h | LCS3-UEPos-Velocity | Rel-7 | TSG | MCC_RAN | BRodilitz@SiRF.com |  |
| 81 | 14.6 | LCS Enhancements Related to Location-Based Services |  | 555d? | 2005-01-03 A | 2007-02-16 A | 100% |  | 2005-01-03 | 2006-06-30 | 390d? |  | finish no earlier than 2007-02-16 | GP | 4440h | 4440h | LCS3-LBS | Rel-7 | TSG | Paolo | kjudge@sirf.com |  |
| 82 | 14.7 | Deleted - RAN2 aspects for LBS | milestone | 0d? | 2005-06-15 A | 2005-06-15 A | 100% |  | 2005-06-15 | 2005-06-15 | 0d? |  | start no earlier than 2005-06-15 | R2 |  |  | LCS3-UEPos-LBS | Rel-7 | TSG | MCC_RAN | BRodilitz@SiRF.com | RP-31 |
| 83 | 15 | **Advanced Global Navigation Satellite System (A-GNSS) concept** |  | 840d? | 2004-06-28 A | 2007-09-15 | 30% | 591.95d? | 2004-06-28 | 2007-09-15 | 840d? | 215d |  | S1 | 18897.6h | 3746.4h | LCS3-AGNSS | Rel-7 | TSG | Michael | Michel.monnerat@space.alcatel.fr |  |
| 84 | 15.1 | Towards A-GNSS Concept |  | 459d? | 2004-08-27 A | 2006-05-31 | 45% | 252.45d? | 2004-08-27 | 2006-05-31 | 459d? | 552d | finish no earlier than 2005-09-29 | S1 | 3672h | 1652.4h | GNSS | Rel-7 | TSG | Paolo | richard.couty@space.alcatel.fr |  |
| 85 | 15.2 | Support for GNSS in GERAN |  | 606.2d? | 2004-06-28 A | 2006-11-17 | 25% | 454.65d? | 2004-06-28 | 2006-11-17 | 606.2d? | 430d | finish no earlier than 2006-11-17 | GP | 4849.6h | 1212.4h | AGNSS-GP | Rel-7 | TSG | Paolo | richard.couty@space.alcatel.fr |  |
| 86 | 15.3 | Global Navigation Satellite System (GNSS) in UTRAN |  | 457d? | 2005-12-15 A | 2007-09-15 | 20% | 365.6d? | 2005-12-15 | 2007-09-15 | 457d? | 215d | finish no earlier than 2007-09-15 | R2 | 3656h | 731.2h | LCS3-GNSS-UTRAN | Rel-7 |  | MCC_RAN | alain.abinakhoul@francetelecom.com |  |
| 87 | 16 | A-GPS Minimum Performance |  | 261d? | 2006-04-28 A | 2007-04-27 | 20% | 208.8d? | 2006-04-28 | 2007-04-27 | 261d? | 315d | finish no earlier than 2007-04-27 | G1; G3 | 2088h | 417.6h | GAGR | Rel-7 |  | Paolo | richard.catmur@spirentcom.com |  |
| 88 | 17 | **Combinational Services** |  | 296d? | 2005-01-17 A | 2006-03-06 A | 100% |  | 2005-01-17 | 2006-03-06 | 296d? |  |  | S1 | 7544h | 7544h | CSICS | Rel-7 | TSG | Michael | Robert.Frank@teliasonera.com |  |
| 89 | 17.1 | Stage 1 for CSICS |  | 104d? | 2005-01-17 A | 2005-06-09 A | 100% |  | 2005-01-17 | 2005-06-09 | 104d? |  | start no earlier than 2005-01-17 | S1 | 832h | 832h |  | Rel-7 | TSG |  |  |  |
| 90 | 17.2 | Stage 2 for CSICS |  | 130d? | 2005-01-17 A | 2005-07-15 A | 100% |  | 2005-01-17 | 2005-07-15 | 130d? |  | start no earlier than 2005-01-17 | S2 | 1040h | 1040h |  | Rel-7 |  |  |  |  |
| 91 | 17.3 | Stage 3 for CSICS CN aspects |  | 221d? | 2005-05-02 A | 2006-03-06 A | 100% |  | 2005-05-02 | 2006-03-06 | 221d? |  | finish no earlier than 2006-03-06 | C1 | 1768h | 1768h |  | Rel-7 | TSG | Andrijana |  |  |
| 92 | 17.4 | Stage 3 for codec aspects |  | 192d? | 2005-03-15 A | 2005-12-07 A | 100% |  | 2005-03-15 | 2005-12-07 | 192d? |  | finish no earlier than 2005-12-07 | S4 | 1536h | 1536h | CSICS-Codec | Rel-7 | TSG | Paolo | Per.Frojdh@ericsson.com |  |
| 93 | 18 | **System enhancements for fixed broadband access to IMS** |  | 876d? | 2003-11-05 A | 2007-03-15 | 83% | 149.96d? | 2003-11-05 | 2007-01-29 | 844d? | 347d |  | S2 | 42097.6h | 27806.6h | FBI | Rel-7 | TSG | Maurice |  |  |
| 94 | 18.1 | **TISPAN Rel 1 related aspects** |  | 808d? | 2003-11-05 A | 2006-12-08 | 85% | 120.17d? | 2003-11-05 | 2006-03-08 | 611d? | 415d |  | S2 | 30896h | 20751.2h |  | Rel-7 |  |  |  |  |
| 95 | 18.1.1 | Stage 2 of FBI for TISPAN R1 |  | 365d? | 2004-10-14 A | 2006-03-08 A | 100% |  | 2004-10-14 | 2006-03-08 | 365d? |  | start no earlier than 2004-10-14 | S2 | 2920h | 2920h |  | Rel-7 |  | Maurice |  |  |
| 96 | 18.1.2 | **Protocol impact of FBI for TISPAN R1** |  | 808d? | 2003-11-05 A | 2006-12-08 | 84% | 127.91d? | 2003-11-05 | 2005-11-30 | 541d? | 415d |  | C1 | 20568h | 17312h |  | Rel-7 | TSG | Andrijana |  |  |
| 97 | 18.1.2.1 | CT1 aspects of FBI for TISPAN R1 |  | 802d? | 2003-11-05 A | 2006-11-30 | 98% | 16.04d? | 2004-08-03 | 2005-11-30 | 347d? | 421d | finish no earlier than 2006-11-30 | C1 | 6416h | 6287.68h |  | Rel-7 | TSG | Andrijana |  |  |
| 98 | 18.1.2.2 | CT3 aspects of FBI for TISPAN R1 |  | 808d? | 2003-11-05 A | 2006-12-08 | 98% | 16.16d? | 2003-11-05 | 2005-03-03 | 347d? | 415d | finish no earlier than 2006-12-08 | C3 | 6464h | 6334.72h |  | Rel-7 | TSG | Andrijana |  |  |
| 99 | 18.1.2.3 | CT4 aspects of FBI for TISPAN R1 |  | 347d? | 2003-11-05 A | 2005-03-03 | 20% | 277.6d? | 2003-11-05 | 2005-03-03 | 347d? | 876d | finish no earlier than 2005-03-03 | C4 | 2776h | 555.2h |  | Rel-7 | TSG | Andrijana |  |  |
| 100 | 18.1.3 | Security Enhancements for FBI |  | 118d? | 2005-06-28 A | 2005-12-08 | 55% | 53.1d? | 2005-06-28 | 2005-12-08 | 118d? | 676d | start no earlier than 2005-06-28 | S3 | 944h | 519.2h | FBI-ISE | Rel-7 |  | Mike | Bengt.Sahlin@ericsson.com |  |

Notes:
- 75: Text3: 22.935 / Text4: Mike Loushine, (Telcordia)
- 76: DAB - Should be SA1 / Text3: 22.935
- 77: Updated WID at SA#32 to change "stage 2" to "study" , duplicated UID 320017 deleted / Text3: 23.837 / Text4: Donghee Shim (LG Electronics Inc.); Patrice HÉDÉ (LG Electronics Mobilecomm France)
- 79: Text3: TS25.305, TS25.453 / Text4: Robert Gross, TruePosition
- 80: Text3: 25.305, 25.331, 25.410, 25.413, 25.453 / Text4: Ben Rodilitz
- 81: Approved at RP#33 as RP-060459 / Text3: 43.059, 44.031, 48.008, 49.031 / Text4: Kevin Judge, SiRF Technologies
- 82: Text3: 25.305, 25.331, 25.410, 25.413, 25.453 / Text4: Ben Rodilitz
- 83: Text4: Michel MONNERAT
- 84: Text4: Richard Couty, ALCATEL SA
- 85: Started / Text4: Richard Couty, ALCATEL SA
- 86: Text3: TS 25.305,TS 25.331,TS 25.306,TS 25.413,TS 25.423,TS 25.433,TS 25.453,TS 25.171,TS 34.171 / Text4: Alain Abinakhoul, France Telecom
- 87: Text3: 45.005, 51.010 / Text4: Richard Catmur, Spirent Communications
- 88: Text4: Robert Frank, TeliaSonera
- 89: Text3: 22.279
- 90: Text3: 23.279
- 91: Text3: New TS 24.279, 24.229, 24.008 / Text4: Peter Dawes (Vodafone)
- 92: Started / Text3: TS 26.141, 26.235, 26.236 / Text4: Per Fröjdh, Ericsson
- 96: Text3: new TR 24.819, 24.229, 29.229, 29.163, 29.209 / Text4: Peter Leis (Siemens)
- 97: end date updated by CT1-chairman after CT#33 / Text3: new TR 24.819, 24.229, 29.229, 29.163, 29.209 / Text4: Siemens
- 98: Text3: new TR, 29.229, 29.163 / Text4: Siemens
- 99: CT4#32: a set of CRs on FBI for cable labs / Text3: 29.209 / Text4: Siemens
- 100: Duplicated entry ("ACCSEC2", "Access Security Enhancements", SP-040865) deleted by A.Sultan / Text3: 33.102, 43.020 / Text4: Bengt Sahlin, Ericsson

| ID | WBS | Task | Type | Duration | Start | Finish | Complete | Remaining | Baseline start | Baseline finish | Baseline duration | Total slack | Constraint | Resources | Work | Actual work | Text1 | Text6 | Text3 | Text4 | Text5 | Text8 | Text7 |
| --- | --- | --- | --- | --- | --- | --- | --- | --- | --- | --- | --- | --- | --- | --- | --- | --- | --- | --- | --- | --- | --- | --- | --- |
| 101 | 18.2 | **PacketCable Related aspects** |  | 291d? | 2006-02-01 A | 2007-03-15 | 74% | 74.65d? | 2006-02-01 | 2006-12-15 | 228d? | 347d |  | S2 | 7296h | 3818.4h | FBI-PCBL | Rel-7 |  |  |  |  |  |
| 102 | 18.2.1 | Stage 2 of FBI for PacketCable |  | 228d? | 2006-02-01 A | 2006-12-15 A | 100% |  | 2006-02-01 | 2006-12-15 | 228d? |  | finish no earlier than 2006-12-15 | S2 | 1824h | 1824h |  | Rel-7 |  |  |  |  |  |
| 103 | 18.2.2 | Protocol impact of FBI for PacketCable |  | 228d? | 2006-05-01 A | 2007-03-15 | 40% | 136.8d? | 2006-05-01 | 2006-11-28 | 152d? | 347d | finish no earlier than 2007-03-15 | C1 | 1824h | 729.6h |  | Rel-7 |  |  |  |  |  |
| 104 | 18.2.3 | SA5 Charging aspects of FBI for PacketCable |  | 186d? | 2006-03-31 A | 2006-12-15 | 85% | 27.9d? | 2006-03-31 | 2006-12-15 | 186d? | 410d | finish no earlier than 2006-12-15 | S5 | 1488h | 1264.8h | FBI-PCBL-CH | Rel-7 | 32.240, 32.260, 32.298, 32.299 | CableLabs | Bernie McKibben | Adrian |  |
| 105 | 19 | Access Security Enhancements |  | 195d? | 2005-01-03 A | 2005-09-30 | 75% | 48.75d? | 2005-01-03 | 2005-09-30 | 195d? | 725d | finish no earlier than 2005-09-30 | S3 | 1560h | 1170h | ACCSEC2 | Rel-7 | 33.102, 43.020 | Bengt Sahlin, Ericsson | Bengt.Sahlin@ericsson.com | Michael | TSG |
| 106 | 20 | **Mp (MRFC - MRFP) interface** |  | 290d? | 2006-02-13 A | 2007-03-23 | 29% | 205.01d? | 2006-02-13 | 2007-03-23 | 290d | 340d |  | C4 | 7048h | 2065.51h | Mp | Rel-7 |  | Emmanuel Gay (Orange) |  | Kimmo |  |
| 107 | 20.1 | CT1 aspects of Mp | milestone | 0d | 2006-02-13 | 2006-02-13 |  |  | 2006-02-13 | 2006-02-13 | 0d | 630d | finish no earlier than 2006-02-13 | C1 |  |  |  | Rel-7 | 24.229 | Orange |  |  |  |
| 108 | 20.2 | CT3 aspects of Mp |  | 160d | 2006-02-13 | 2006-09-22 |  |  | 2006-02-13 | 2006-09-22 | 160d | 470d | start no earlier than 2006-02-13 | C3 | 1280h |  |  | Rel-7 | 29.162 | Orange |  |  |  |
| 109 | 20.3 | Procedures description |  | 141d? | 2006-06-02 A | 2006-12-15 | 20% | 112.8d? |  |  |  | 410d | finish no earlier than 2006-12-15 | C4 | 1128h | 225.6h |  | Rel-7 | 23.333 | Huawei |  | Kimmo |  |
| 110 | 20.4 | Stage 3 |  | 290d | 2006-02-13 A | 2007-03-23 | 50% | 145d | 2006-02-13 | 2007-03-23 | 290d | 340d | finish no earlier than 2007-03-23 | C4 | 2320h | 1160h |  | Rel-7 | 29.333 | Orange |  | Kimmo |  |
| 111 | 21 | IMS Stage 3 IETF Protocol alignment |  | 589d? | 2004-12-10 A | 2007-03-15 | 75% | 147.25d? | 2004-12-10 | 2006-09-15 | 461d? | 347d | finish no earlier than 2007-03-15 | C1 | 4712h | 3534h | IMSProtoc | Rel-7 | TR 24.930 |  |  |  |  |
| 112 | 22 | **Support of SMS over generic 3GPP IP access.** |  | 630d? | 2004-10-14 A | 2007-03-15 | 59% | 257.69d? | 2004-10-14 | 2006-09-15 | 502d? | 347d |  | S2 | 20128h | 9462.68h | SMSIP | Rel-7 | TR 23.abc, TS 23.abc | Wenlin Zhang (Huawei) | zhangwenlin@huawei.com | Maurice | TSG |
| 113 | 22.1 | FS on SMSIP |  | 173d? | 2004-10-14 A | 2005-06-13 A | 100% |  | 2004-10-14 | 2005-06-13 | 173d? |  | start no earlier than 2004-10-14 | S2 | 1384h | 1384h |  | Rel-7 | 23.804 |  |  |  |  |
| 114 | 22.2 | Stage 2 for SMSIP |  | 333d? | 2005-06-08 A | 2006-09-15 | 85% | 49.95d? | 2005-06-08 | 2006-09-15 | 333d? | 475d | finish no earlier than 2006-09-15 | S2 | 2664h | 2264.4h |  | Rel-7 | 23.204 |  |  |  |  |
| 115 | 22.3 | **Stage 3 for SMSIP** |  | 461d? | 2005-06-08 A | 2007-03-15 | 42% | 267.33d? | 2005-06-08 | 2006-09-08 | 328d? | 347d |  | C4 | 11040h | 4637.88h |  | Rel-7 |  |  |  |  |  |
| 116 | 22.3.1 | CT1 aspects for SMSIP |  | 461d? | 2005-06-08 A | 2007-03-15 | 45% | 253.55d? | 2005-06-08 | 2006-09-08 | 328d? | 347d | finish no earlier than 2007-03-15 | C1 | 3688h | 1659.6h |  | Rel-7 |  |  |  |  |  |
| 117 | 22.3.2 | CT4 aspects for SMSIP |  | 458d? | 2005-06-08 A | 2007-03-09 | 39% | 279.38d? | 2005-06-08 | 2006-09-08 | 328d? | 350d | finish no earlier than 2007-03-09 | C4 | 3664h | 1428.96h |  | Rel-7 |  |  |  |  |  |
| 118 | 23 | **Evolution of Policy Control and Charging** |  | 627d? | 2004-10-14 A | 2007-03-09 | 58% | 262.89d? | 2004-10-14 | 2006-12-15 | 567d? | 350d |  | S2 | 21896h | 12118.8h | PCC | Rel-7 |  |  |  | Maurice | TSG |
| 119 | 23.1 | TR for PCC |  | 315d? | 2004-10-14 A | 2005-12-29 A | 100% |  | 2004-10-14 | 2005-12-29 | 315d? |  | finish no earlier than 2005-12-28 | S2 | 2520h | 2520h |  | Rel-7 |  |  |  |  |  |
| 120 | 23.2 | Stage 2 for PCC |  | 315d? | 2005-07-04 A | 2006-09-15 A | 100% |  | 2005-07-04 | 2006-09-15 | 315d? |  | finish no earlier than 2006-09-15 | S2 | 2520h | 2520h |  | Rel-7 | 23.203 |  |  |  |  |
| 121 | 23.3 | Evolution of policy control and flow based bearer level charging |  | 109d? | 2006-08-01 | 2006-12-29 |  |  | 2006-06-30 | 2006-12-08 | 116d? | 400d | start no earlier than 2006-08-01 | S2 | 872h |  |  | Rel-7 | 23.207, 23.125, 23.002, 23.228 | Balazs Bertenyi (Nokia) | balazs.bertenyi@nokia.com |  |  |
| 122 | 23.4 | SA5 Charging aspects of PCC |  | 186d? | 2006-03-31 A | 2006-12-15 | 10% | 167.4d? | 2006-03-31 | 2006-12-15 | 186d? | 410d | finish no earlier than 2006-12-15 | S5 | 1488h | 148.8h | PCC-CH | Rel-7 | 32.250, 32.251, 32.298, 32.299 | Orange | alain.bibas@orange-ft.com | Adrian |  |
| 123 | 23.5 | Gx reference point for Policy and Charging Control |  | 331d? | 2005-12-02 A | 2007-03-09 | 60% | 132.4d? | 2005-12-02 | 2006-11-30 | 260d? | 350d | finish no earlier than 2007-03-09 | C3 | 2648h | 1588.8h |  | Rel-7 | 29.210, 29.207, 29.208 | Thomas Belling (Siemens) | thomas.belling@siemens.com | Seung Don |  |
| 124 | 23.6 | **Rx reference point for PCC CT3 aspects** |  | 331d? | 2005-12-02 A | 2007-03-09 | 36% | 213.35d? | 2005-12-02 | 2006-11-30 | 260d? | 350d |  | C3 | 6832h | 2428.3h | PCC-Rx | Rel-7 | 29.209, 29.211, 24.229 | Javier Pastor (Ericsson) | j.javier.pastor@ericsson.com | Seung Don |  |
| 125 | 23.6.1 | PCC-Rx CT3 aspects |  | 331d? | 2005-12-02 A | 2007-03-09 | 55% | 148.95d? | 2005-12-02 | 2006-11-30 | 260d? | 350d | finish no earlier than 2007-03-09 | C3 | 2648h | 1456.4h |  | Rel-7 | 29.209, 29.211, 24.229 | Javier Pastor (Ericsson) | j.javier.pastor@ericsson.com | Seung Don |  |
| 126 | 23.6.2 | PCC-Rx CT1 aspects |  | 192d? | 2005-12-02 A | 2006-10-30 | 2% | 188.16d? | 2005-12-02 | 2006-09-29 | 172d? | 445d | finish no earlier than 2006-10-30 | C1 | 1536h | 30.72h |  | Rel-7 |  |  |  |  |  |
| 127 | 24 | Video Codec Performance Requirements |  | 504d? | 2005-01-03 A | 2006-12-07 | 60% | 201.6d? | 2005-01-03 | 2006-12-07 | 504d? | 416d | finish no earlier than 2006-12-07 | S4 | 4032h | 2419.2h | VICPer | Rel-7 | 26.234, 26.235, 26.346, 26.140 | Juergen Pandel (Siemens AG) | juergen.pandel@siemens.com | Paolo | TSG |
| 128 | 25 | DIAMETER on the GGSN Gi interface |  | 586d? | 2004-09-10 A | 2006-12-08 | 85% | 87.9d? | 2004-09-10 | 2006-09-22 | 531d? | 415d | finish no earlier than 2006-12-08 | C3 | 4688h | 3984.8h | DIAMGi | Rel-7 | 29.061 | Nico Gabriele (Vodafone) | Nico.Gabriele@vodafone.com | Seung Don | TSG |
| 129 | 26 | DIAMETER on the PDG Wi inteface |  | 586d? | 2004-09-10 A | 2006-12-08 | 60% | 234.4d? | 2004-09-10 | 2006-09-22 | 531d? | 415d | finish no earlier than 2006-12-08 | C3 | 4688h | 2812.8h | DIAMWi | Rel-7 | 29.161 | Nico Gabriele (Vodafone) | Nico.Gabriele@vodafone.com | Seung Don | TSG |

Notes:
- 104: 03/2006 SA#31 WID approved
- 105: WID approved SA#26. Record created after SA#27. It is about improved GERAN security
- 110: indication in CT4#31 50%
- 111: TR 24.930: Signalling flows for the session setup in the IM CN subsystem based on Session Initiation Protocol (SIP)
- 112: Revised at SP#29
- 117: CT4#32: Stage 2 CR still outstanding.
- 121: Approved at SP#29. 23.125 will be discontinued from Release 7.
- 122: 03/2006 SA#31 WID approved
- 123: Approved at CP#30, Revised at CP#31, Revised at CP#33
- 124: Approved at CP#30, Revised at CP#31, Revised at CP#33
- 125: Approved at CP#30, Revised at CP#31
- 128: 13/12/2005 08:00, Revised at CP#33
- 129: 13/12/2005 08:00, Revised at CP#33

| ID | WBS | Task | Type | Duration | Start | Finish | Complete | Remaining | Baseline start | Baseline finish | Baseline duration | Total slack | Constraint | Resources | Work | Actual work | Text1 | Text4 | Text5 | Text6 | Text7 | Text8 |
| --- | --- | --- | --- | --- | --- | --- | --- | --- | --- | --- | --- | --- | --- | --- | --- | --- | --- | --- | --- | --- | --- | --- |
| 130 | 27 | **CAMEL Trunk Triggers** |  | 251d? | 2004-12-17 A | 2005-12-05 A | 100% |  | 2004-12-17 | 2005-12-05 | 251d? |  |  | S1 | 6024h | 6024h | TTCAMEL | Amar Deol, Nortel Networks | deola@nortelnetworks.com | Rel-7 | TSG | Michael |
| 131 | 27.1 | Stage 1 for CAMEL Trunk Triggers |  | 251d? | 2004-12-17 A | 2005-12-05 A | 100% |  | 2004-12-17 | 2005-12-05 | 251d? |  |  | S1 | 2008h | 2008h |  | Amar Deol, Nortel Networks | deola@nortelnetworks.com | Rel-7 | TSG | Michael |
| 132 | 27.2 | CAMEL Trunk Originated Trigger Detection Points |  | 251d? | 2004-12-17 A | 2005-12-05 A | 100% |  | 2004-12-17 | 2005-12-05 | 251d? |  | start no earlier than 2004-12-17 | C4 | 2008h | 2008h | CamelR7 | David Hutton, Nortel Networks | dhutton@nortel.com | Rel-7 | TSG | Kimmo |
| 133 | 28 | MS Antenna Performance Evaluation Method and Requirements |  | 471d? | 2005-01-28 A | 2006-11-17 | 75% | 117.75d? | 2005-01-28 | 2006-06-30 | 371d? | 430d | finish no earlier than 2006-11-17 | G1 | 3768h | 2826h | APEMR | Ulf.Tegth (TeliaSonera) | Ulf.Tegth@teliasonera.com | Rel-7 | TSG | Paolo |
| 134 | 29 | **Lower 700 MHz Inclusion in the GERAN Specifications** |  | 390d? | 2005-01-03 A | 2006-06-30 A | 100% |  | 2005-01-03 | 2006-06-30 | 390d? |  |  | GP | 7632h | 7632h | GSM710 | Dave Cotton (UTC) | dcotton@mtview.union-tel.com | Rel-7 | TSG | Paolo |
| 135 | 29.1 | Inclusion of the 698 – 746 MHz band into GERAN core specifications |  | 129d? | 2005-01-03 A | 2005-06-30 A | 100% |  | 2005-01-03 | 2005-06-30 | 129d? |  | finish no earlier than 2005-06-30 | G1 | 1032h | 1032h | GSM710-core |  |  | Rel-7 |  | Paolo |
| 136 | 29.2 | G1 aspects of GSM710 |  | 217.5d? | 2005-08-31 A | 2006-06-30 A | 100% |  | 2005-08-31 | 2006-06-30 | 217.5d? |  | finish no earlier than 2006-06-30 | G1 | 1740h | 1740h | GSM-710-test |  |  | Rel-7 |  | Paolo |
| 137 | 29.3 | G3 aspects of GSM710 |  | 217.5d? | 2005-08-31 A | 2006-06-30 A | 100% |  | 2005-08-31 | 2006-06-30 | 217.5d? |  | finish no earlier than 2006-06-30 | G3 | 1740h | 1740h | GSM-710-test |  |  | Rel-7 |  | Stoyan |
| 138 | 30 | **Enhancements of VGCS for public authority officials** |  | 580d? | 2004-08-27 A | 2006-11-16 | 94% | 33.26d? | 2004-08-27 | 2006-09-15 | 536d? | 431d |  | S1 | 21064h | 15728h | EVGCS | Siemens |  | Rel-7 | TSG | Andrijana |
| 139 | 30.1 | Stage 1 | milestone | 0d? | 2004-08-27 A | 2004-08-27 A | 100% |  | 2004-08-27 | 2004-08-27 | 0d? |  | finish no earlier than 2004-08-27 | S1 |  |  |  | Joerg Swetina (Siemens AG) | joerg.swetina@SIEMENS.COM | Rel-7 | TSG | Michael |
| 140 | 30.2 | **Architecture and protocol aspects** |  | 536d? | 2004-08-27 A | 2006-09-15 A | 100% |  | 2004-08-27 | 2006-09-15 | 536d? |  |  | C1 | 11784h | 11784h |  | Robert Zaus (Siemens) |  | Rel-7 |  |  |
| 141 | 30.2.1 | CT1 aspects of EVGCS |  | 536d? | 2004-08-27 A | 2006-09-15 A | 100% |  | 2004-08-27 | 2006-09-15 | 536d? |  | finish no earlier than 2006-09-15 | C1 | 4288h | 4288h |  | Siemens |  | Rel-7 |  |  |
| 142 | 30.2.2 | CT4 aspects of EVGCS |  | 401d? | 2004-08-27 A | 2006-03-10 A | 100% |  | 2004-08-27 | 2006-03-10 | 401d? |  | finish no earlier than 2006-03-10 | C4 | 3208h | 3208h |  | Siemens |  | Rel-7 |  |  |
| 143 | 30.3 | GERAN2 aspects |  | 580d? | 2004-08-27 A | 2006-11-16 | 85% | 87d? | 2004-08-27 | 2006-06-30 | 481d? | 431d | finish no earlier than 2006-11-16 | G2 | 4640h | 3944h |  | Ken Isaacs (Siemens) | kenneth.isaacs@roke.co.uk | Rel-7 | TSG | Gert |
| 144 | 31 | **Improvements of VGCS for parallel use of services** |  | 523d? | 2005-03-15 A | 2007-03-15 | 42% | 303.78d? | 2005-03-15 | 2006-08-29 | 381d? | 346d |  | S1 | 13862.2h | 3640.08h | IVGCS |  |  | Rel-7 |  |  |
| 145 | 31.1 | Service Requirements for VGCS improvements |  | 62d? | 2005-03-15 A | 2005-06-08 A | 100% |  | 2005-03-15 | 2005-06-08 | 62d? |  | finish no earlier than 2005-06-08 | S1 | 496h | 496h |  | Kurt Bischinger (T-Mobile) | kurt.bischinger@t-mobile.at | Rel-7 | TSG | Michael |
| 146 | 31.2 | Stage 2 modifications for VGCS improvements |  | 207d? | 2005-12-01 A | 2006-09-15 A | 100% |  | 2005-12-01 | 2006-06-16 | 142d? |  | finish no earlier than 2006-09-15 | C1 | 1656h | 1656h |  | Kurt Bischinger (T-Mobile) | kurt.bischinger@t-mobile.at | Rel-7 | TSG |  |
| 147 | 31.3 | **Protocol aspects** |  | 336d? | 2005-12-01 A | 2007-03-15 | 19% | 273.75d? | 2005-12-01 | 2006-08-29 | 194d? | 346d |  | C1 | 8032h | 1488.08h |  | Dieter Jacobsohn (T-Mobile) |  | Rel-7 |  |  |
| 148 | 31.3.1 | CT1 aspects of IVGCS |  | 336d? | 2005-12-01 A | 2007-03-15 | 23% | 258.72d? | 2005-12-01 | 2006-08-29 | 194d? | 346d | finish no earlier than 2007-03-15 | C1 | 2688h | 618.24h |  | T-Mobile |  | Rel-7 |  |  |
| 149 | 31.3.2 | CT4 aspects of IVGCS |  | 332d? | 2005-12-01 A | 2007-03-09 | 14% | 285.52d? | 2005-12-01 | 2006-08-29 | 194d? | 350d | finish no earlier than 2007-03-09 | C4 | 2656h | 371.84h |  | T-mobile |  | Rel-7 |  |  |
| 150 | 32 | **OSA Rel-7** |  | 449d? | 2005-03-15 A | 2006-12-01 | 70% | 133.1d? | 2005-03-15 | 2006-12-01 | 449d? | 420d |  | S1 | 11576h | 7364h | OSA7 | Eamonn Murray (AePONA) | eamonn.murray@aepona.com | Rel-7 | TSG | Michael |
| 151 | 32.1 | Service Requirements for OSA Service Broker |  | 62d? | 2005-03-15 A | 2005-06-08 A | 100% |  | 2005-03-15 | 2005-06-08 | 62d? |  | finish no earlier than 2005-06-08 | S1 | 496h | 496h | OSA7-SB | Eamonn Murray (AePONA) | eamonn.murray@aepona.com | Rel-7 | TSG | Michael |
| 152 | 32.2 | Stage 2 OSA API Service Brokering |  | 156d? | 2006-04-28 A | 2006-12-01 A | 100% |  | 2006-04-28 | 2006-12-01 | 156d? |  |  | C5 | 1248h | 1248h | OSA7-SB | Eamonn Murray (AePONA) | eamonn.murray@aepona.com | Rel-7 | TSG | Adrian |
| 153 | 32.3 | Stage 3 OSA API Service Brokering |  | 156d? | 2006-04-28 A | 2006-12-01 | 60% | 62.4d? | 2006-04-28 | 2006-12-01 | 156d? | 420d | finish no earlier than 2006-12-01 | C5 | 1248h | 748.8h | OSA7-SB | Eamonn Murray (AePONA) |  | Rel-7 |  |  |

Notes:
- 131: Text3: 22.078
- 132: Not started
- 133: Started / Text3: 25.9xx, 45.005
- 134: Text3: 24.008, 43.022, 44.018, 44.118, 45, 001, 45.005, 51.010, 51.021
- 135: Completed / Text3: 24.008, 43.022, 44.018, 44.118, 45, 001, 45.005,
- 136: Text3: 51.021
- 137: Text3: 51.010
- 138: Text3: 43.068, 44.068, 24.008, 29.002
- 139: Text3: 42.068, 43.068
- 140: Text3: 43.068, 44.068
- 141: Text3: 43.068, 44.068, 24.008
- 142: Text3: 29.002
- 145: "completeed" as from Chris S' e-mail / Text3: 42.068
- 146: Updated by CT1 chair / Text3: 43.068
- 147: Previous name (before CT32) was Architecture and protocol aspects / Text3: 44.068
- 148: end date updated by CT1-chairman after CT#33 / Text3: 43.068, 44.068, 24.008
- 149: Text3: 29.002
- 151: az: WID URL corrected / Text3: 22.127
- 152: Text3: 23.198
- 153: Text3: 29.198-16

| ID | WBS | Task | Type | Duration | Start | Finish | Complete | Remaining | Baseline start | Baseline finish | Baseline duration | Total slack | Constraint | Resources | Work | Actual work | Text1 | Text4 | Text5 | Text6 | Text8 | Text7 | Text10 |
| --- | --- | --- | --- | --- | --- | --- | --- | --- | --- | --- | --- | --- | --- | --- | --- | --- | --- | --- | --- | --- | --- | --- | --- |
| 154 | 32.4 | **OSA Stage 2/3 enhancements** |  | 156d? | 2006-04-28 A | 2006-12-01 | 60% | 62.4d? | 2006-04-28 | 2006-12-01 | 156d? | 420d |  | C5 | 4992h | 2344h | OSA7 | Damian O’Neill (AePONA) | damian.oneill@aepona.com | Rel-7 | Adrian |  |  |
| 155 | 32.4.1 | Parlay X Message Broadcast |  | 156d? | 2006-04-28 A | 2006-12-01 | 60% | 62.4d? | 2006-04-28 | 2006-12-01 | 156d? | 420d | finish no earlier than 2006-12-01 | C5 | 1248h | 748.8h |  | Mr. JeongHwan Kim (ETRI) |  | Rel-7 |  |  |  |
| 156 | 32.4.2 | Parlay X Geocoding and Mapping |  | 156d? | 2006-04-28 A | 2006-12-01 | 60% | 62.4d? | 2006-04-28 | 2006-12-01 | 156d? | 420d | finish no earlier than 2006-12-01 | C5 | 1248h | 748.8h |  | Mrs. Hyunkyung Yoo (ETRI) |  | Rel-7 |  |  |  |
| 157 | 32.4.3 | Parlay X Application driven QoS |  | 156d? | 2006-04-28 A | 2006-12-01 | 60% | 62.4d? | 2006-04-28 | 2006-12-01 | 156d? | 420d | finish no earlier than 2006-12-01 | C5 | 1248h | 748.8h |  | Mr. Darren Gunning |  | Rel-7 |  |  |  |
| 158 | 33 | Dynamic and interactive multimedia scenes |  | 453d? | 2005-03-15 A | 2006-12-07 | 45% | 249.15d? | 2005-03-15 | 2006-12-07 | 453d? | 416d | finish no earlier than 2006-12-07 | S4 | 3624h | 1630.8h | DIMS | Gaëlle MARTIN-COCHER (Streamezzo) | gaelle.martin-cocher@streamezzo.com | Rel-7 | Paolo | TSG |  |
| 159 | 34 | Liberty Alliance and 3GPP Security Interworking |  | 451d? | 2005-03-10 A | 2006-11-30 | 90% | 45.1d? | 2005-03-10 | 2005-09-30 | 147d? | 421d | finish no earlier than 2006-11-30 | S3 | 3608h | 3247.2h | LibSec | Silke Holtmanns, Nokia | Silke.Holtmanns@NOKIA.COM | Rel-7 | Maurice | TSG |  |
| 160 | 35 | **WLAN-UMTS Interworking Phase 2** |  | 371d? | 2004-01-05 A | 2005-06-07 | 99% | 0d? | 2004-01-05 | 2005-06-07 | 371d? | 809d |  | S1 | 3888h | 3888h | WLAN2 | Fredric Paint, Telenor | frederic.paint@telenor.com | Rel-7 | Michael | TSG |  |
| 161 | 35.1 | Stage 1 on Session Continuity |  | 115d? | 2004-01-05 A | 2004-06-11 A | 100% |  | 2004-01-05 | 2004-06-11 | 115d? |  | start no earlier than 2004-01-05 | S1 | 920h | 920h | WLAN-SC |  |  | Rel-7 |  |  | SP-24 |
| 162 | 35.2 | Stage 2 on Session Continuity: covered by SAE | milestone | 0d? | 2005-06-07 | 2005-06-07 |  |  | 2005-06-07 | 2005-06-07 | 0d? | 809d | finish no earlier than 2005-06-07 | S2 |  |  |  |  |  | Rel-7 |  |  |  |
| 163 | 36 | **WLAN Interworking – Private Network access from WLAN 3GPP IP Access** |  | 252d? | 2005-10-10 A | 2006-09-26 A | 100% |  | 2005-10-10 | 2006-09-26 | 252d? |  |  | S2 | 6920h | 6920h | WLANPNA |  |  | Rel-7 | Maurice |  |  |
| 164 | 36.1 | WLAN-PNA - Stage 2 |  | 185d? | 2005-10-10 A | 2006-06-23 A | 100% |  | 2005-10-10 | 2006-06-23 | 185d? |  | start no earlier than 2005-10-10 | S2 | 1480h | 1480h | WLANPNA-st2 | Toshiyuki Tamura (NEC) | tamurato@aj.jp.nec.com | Rel-7 | Maurice |  |  |
| 165 | 36.2 | **WLAN-PNA - Stage 3** |  | 170d? | 2006-02-01 A | 2006-09-26 A | 100% |  | 2006-02-01 | 2006-09-26 | 170d? |  |  | C1 | 5440h | 5440h | WLANPNA-st3 | Pierre-Jean Muller (NEC) | pierre-jean.muller@nectech.fr | Rel-7 | Andrijana | TSG |  |
| 166 | 36.2.1 | CT1 aspets for WLAN-PNA |  | 170d? | 2006-02-01 A | 2006-09-26 A | 100% |  | 2006-02-01 | 2006-09-26 | 170d? |  | start no earlier than 2006-02-01 | C1 | 1360h | 1360h | WLANPNA-st3 | Pierre-Jean Muller (NEC) | pierre-jean.muller@nectech.fr | Rel-7 | Andrijana |  |  |
| 167 | 36.2.2 | CT3 aspets for WLAN-PNA |  | 170d? | 2006-02-01 A | 2006-09-26 A | 100% |  | 2006-02-01 | 2006-09-26 | 170d? |  | start no earlier than 2006-02-01 | C3 | 1360h | 1360h | WLANPNA-st3 | Pierre-Jean Muller (NEC) | pierre-jean.muller@nectech.fr | Rel-7 | Andrijana |  |  |
| 168 | 36.2.3 | CT4 aspets for WLAN-PNA |  | 170d? | 2006-02-01 A | 2006-09-26 A | 100% |  | 2006-02-01 | 2006-09-26 | 170d? |  | start no earlier than 2006-02-01 | C4 | 1360h | 1360h | WLANPNA-st3 | Pierre-Jean Muller (NEC) | pierre-jean.muller@nectech.fr | Rel-7 | Andrijana |  |  |
| 169 | 37 | **Enhancements to support QoS provisioning over 3GPP/WLAN Interworking** |  | 520d? | 2005-03-14 A | 2007-03-09 | 75% | 129.66d? | 2005-03-14 | 2006-06-30 | 340d? | 350d |  | S2 | 7848h | 5891.11h | WLAN-QOS | Osok Song, Samsung | osok.song@samsung.com | Rel-7 | Maurice |  |  |
| 170 | 37.1 | TR on support of QoS on WLAN |  | 232d? | 2005-03-14 A | 2006-01-31 A | 100% |  | 2005-03-14 | 2006-01-31 | 232d? |  | start no earlier than 2005-03-14 | S2 | 1856h | 1856h |  |  |  | Rel-7 |  |  |  |
| 171 | 37.2 | Stage 2 on support of QoS over 3GPP/WLAN interworking |  | 108d? | 2006-02-01 A | 2006-06-30 A | 100% |  | 2006-02-01 | 2006-06-30 | 108d? |  | start no earlier than 2006-02-01 | S2 | 864h | 864h |  |  |  | Rel-7 |  |  |  |
| 172 | 37.3 | Stage 3 on support of QoS over 3GPP/WLAN Interworking |  | 121d? | 2006-09-22 A | 2007-03-09 | 5% | 114.95d? |  |  |  | 350d | finish no earlier than 2007-03-09 | C4 | 968h | 48.4h | WLAN-QOS | Peng Zhang, Huawei | zhang.peng@huawei.com | Rel-7 |  |  |  |
| 173 | 38 | **Voice call continuity between CS and IMS (incl. I-WLAN)** |  | 571d? | 2004-12-31 A | 2007-03-09 | 55% | 257.75d? | 2004-12-31 | 2006-12-15 | 511d? | 350d |  | S2 | 18328h | 7514.43h | VCC | Andy Bennett, Lucent; Roger Bunting, Cingular | andybennett@lucent.com | Rel-7 | Maurice |  |  |
| 174 | 38.1 | TR for VCC |  | 245d? | 2004-12-31 A | 2005-12-08 A | 100% |  | 2004-12-31 | 2005-12-08 | 245d? |  | finish no earlier than 2005-12-08 | S2 | 1960h | 1960h |  |  |  | Rel-7 |  |  |  |
| 175 | 38.2 | Stage 1 for VCC |  | 140d? | 2005-03-17 A | 2005-09-28 A | 100% |  | 2005-03-17 | 2005-09-28 | 140d? |  | finish no earlier than 2005-09-28 | S1 | 1120h | 1120h |  |  |  | Rel-7 | Mike |  |  |
| 176 | 38.3 | Stage 2 for VCC |  | 264d? | 2005-09-06 A | 2006-09-08 A | 100% |  | 2005-09-06 | 2006-09-08 | 264d? |  | finish no earlier than 2006-09-08 | S2 | 2112h | 2112h |  |  |  | Rel-7 |  |  |  |
| 177 | 38.4 | **Stage 3 for VCC** |  | 288d? | 2006-02-01 A | 2007-03-09 | 20% | 230.6d? | 2006-02-01 | 2006-11-01 | 196d? | 350d |  | C1 | 7000h | 1395.23h |  | Keith Drage (Lucent) | drage@lucent.com | Rel-7 |  |  |  |
| 178 | 38.4.1 | CT1 aspects of VCC |  | 195d? | 2006-02-01 A | 2006-11-01 | 60% | 78d? | 2006-02-01 | 2006-11-01 | 196d? | 443d | finish no earlier than 2006-11-01 | C1 | 1560h | 936h |  | Keith Drage (Lucent) | drage@lucent.com | Rel-7 |  |  |  |
| 179 | 38.4.2 | CT3 aspects of VCC |  | 196d? | 2006-02-01 | 2006-11-01 |  |  | 2006-02-01 | 2006-11-01 | 196d? | 442d | start no earlier than 2006-02-01 | C3 | 1568h |  |  | Keith Drage (Lucent) | drage@lucent.com | Rel-7 |  |  |  |
| 180 | 38.4.3 | CT4 aspects of VCC |  | 196d? | 2006-06-09 | 2007-03-09 |  |  | 2006-02-01 | 2006-11-01 | 196d? | 350d | start no earlier than 2006-06-09 | C4 | 1568h |  |  | Keith Drage (Lucent) | drage@lucent.com | Rel-7 |  |  |  |
| 181 | 38.5 | SA5 Charging aspects of VCC |  | 196d? | 2006-03-17 A | 2006-12-15 | 10% | 176.4d? | 2006-03-17 | 2006-12-15 | 196d? | 410d | finish no earlier than 2006-12-15 | S5 | 1568h | 156.8h | VCC-CH | Orange | alain.bibas@orange-ft.com | Rel-7 | Adrian |  |  |

Notes:
- 154: CT#30: WID approved. / Text3: 23.198, 29.198,29.998,29.199
- 155: Text3: 29.199-15
- 156: Text3: 29.199-16
- 157: Text3: 29.199-17
- 158: Text3: 26.234, 23.346, 26.140, 26.244
- 159: WID approved SA#27. / Text3: 33.980
- 160: Created at TSG#27 by A. Sultan because of WLAN items belonging to Rel-7
- 163: Placeholder created to Hold SA2 and CT1 BBs
- 164: Approved at SP#29 / Text3: 23.234, 33.234
- 165: Approved at CP#29
- 166: Approved at CP#29 / Text3: 24.234
- 167: Approved at CP#29 / Text3: 29.161
- 168: CT4#31; no impacts identified, therefor completed / Text3: 29.234
- 169: Moved from FS section Feb 06 / Text3: 23.836
- 172: Text3: 24.234, 29.234, 23.008
- 173: WID approved SA#27. Revised at SA#28. WID update approved at SA#32 / Text3: 22.101, 23.228, 32.250, 32.260, 32.299, 32.298
- 174: Text3: 23.806
- 176: Text3: 23.206
- 177: Text3: new TS, 24.229, 23.008, 23.009, 23.078, 29.078, 29.163, 29.228, 29.229, 29.230, 29.278, 29.328, 29.329
- 178: Text3: new TS, 24.229
- 179: Text3: 29.163
- 180: Text3: 23.008, 23.009, 23.078, 29.078, 29.228, 29.229, 29.230, 29.278, 29.328, 29.329
- 181: 03/2006 SA#31 WID approved / Text3: 32.250, 32.260, 32.298, 32.299

| ID | WBS | Task | Duration | Start | Finish | Complete | Remaining | Baseline start | Baseline finish | Baseline duration | Total slack | Constraint | Resources | Work | Actual work | Text1 | Text4 | Text5 | Text6 | Text7 | Text8 |
| --- | --- | --- | --- | --- | --- | --- | --- | --- | --- | --- | --- | --- | --- | --- | --- | --- | --- | --- | --- | --- | --- |
| 182 | 39 | **OAM&P** | 869d? | 2004-02-16 A | 2007-06-15 | 60% | 346.67d? | 2004-02-16 | 2006-12-15 | 740d? | 281d |  | S5 | 94178.2h | 49943.7h | OAM7 | Christian TOCHE | Christian.Toche@huawei.com | Rel-7 | TSG | Adrian |
| 183 | 39.1 | **Network Infrastructure Management** | 336d? | 2005-09-02 A | 2006-12-15 | 64% | 120.03d? | 2005-09-02 | 2006-12-15 | 336d? | 410d |  | S5 | 41152h | 24723.2h | OAM7-NIM |  |  | Rel-7 |  |  |
| 184 | 39.1.1 | Enhance NRM to accommodate NGN (IMS as basis of the Next Generation Network) | 336d? | 2005-09-02 A | 2006-12-15 | 35% | 218.4d? | 2005-09-02 | 2006-12-15 | 336d? | 410d | finish no earlier than 2006-12-15 | S5 | 2688h | 940.8h |  | Motorola |  | Rel-7 |  |  |
| 185 | 39.1.2 | Co-operative Element Management interface (CO-OP) (Study + Implementation) | 336d? | 2005-09-02 A | 2006-12-15 | 95% | 16.8d? | 2005-09-02 | 2006-12-15 | 336d? | 410d | finish no earlier than 2006-12-15 | S5 | 2688h | 2553.6h |  | Motorola |  | Rel-7 |  |  |
| 186 | 39.1.3 | Network Management (NM) Itf-N performance criteria | 336d? | 2005-09-02 A | 2006-12-15 | 65% | 117.6d? | 2005-09-02 | 2006-12-15 | 336d? | 410d | finish no earlier than 2006-12-15 | S5 | 2688h | 1747.2h |  | China Mobile |  | Rel-7 |  |  |
| 187 | 39.1.4 | Delta synchronization between IRP Manager and IRP Agent (Study + Implementation) | 336d? | 2005-09-02 A | 2006-12-15 | 65% | 117.6d? | 2005-09-02 | 2006-12-15 | 336d? | 410d | finish no earlier than 2006-12-15 | S5 | 2688h | 1747.2h |  | Siemens |  | Rel-7 |  |  |
| 188 | 39.1.5 | Subscription Management (SuM) IRP Solution Sets | 336d? | 2005-09-02 A | 2006-12-15 | 90% | 33.6d? | 2005-09-02 | 2006-12-15 | 336d? | 410d | finish no earlier than 2006-12-15 | S5 | 2688h | 2419.2h |  | Ericsson |  | Rel-7 |  |  |
| 189 | 39.1.6 | Integration Reference Point (IRP) Security Management | 336d? | 2005-09-02 A | 2006-12-15 | 90% | 33.6d? | 2005-09-02 | 2006-12-15 | 336d? | 410d | finish no earlier than 2006-12-15 | S5 | 2688h | 2419.2h |  | Huawei |  | Rel-7 |  |  |
| 190 | 39.1.7 | Integration Reference Point (IRP) Methodology | 336d? | 2005-09-02 A | 2006-12-15 | 60% | 134.4d? | 2005-09-02 | 2006-12-15 | 336d? | 410d | finish no earlier than 2006-12-15 | S5 | 2688h | 1612.8h |  | Ericsson |  | Rel-7 |  |  |
| 191 | 39.1.8 | Partial suspension of Itf-N during maintenance/testing (Study + Implementation) | 336d? | 2005-09-02 A | 2006-12-15 | 80% | 67.2d? | 2005-09-02 | 2006-12-15 | 336d? | 410d | finish no earlier than 2006-12-15 | S5 | 2688h | 2150.4h |  | Siemens |  | Rel-7 |  |  |
| 192 | 39.1.9 | Advanced Alarming on Itf-N (Study + Implementation) | 336d? | 2005-09-02 A | 2006-12-15 | 60% | 134.4d? | 2005-09-02 | 2006-12-15 | 336d? | 410d | finish no earlier than 2006-12-15 | S5 | 2688h | 1612.8h |  | Siemens |  | Rel-7 |  |  |
| 193 | 39.1.10 | Management of Legacy Equipment | 336d? | 2005-09-02 A | 2006-12-15 | 20% | 268.8d? | 2005-09-02 | 2006-12-15 | 336d? | 410d | finish no earlier than 2006-12-15 | S5 | 2688h | 537.6h |  | Siemens |  | Rel-7 |  |  |
| 194 | 39.1.11 | Rules for Vendor Specific Extensions | 336d? | 2005-09-02 A | 2006-12-15 | 60% | 134.4d? | 2005-09-02 | 2006-12-15 | 336d? | 410d | finish no earlier than 2006-12-15 | S5 | 2688h | 1612.8h |  | Siemens |  | Rel-7 |  |  |
| 195 | 39.1.12 | CN CS Bearer Transport Network (BTN) relative NRM | 336d? | 2005-09-02 A | 2006-12-15 | 70% | 100.8d? | 2005-09-02 | 2006-12-15 | 336d? | 410d | finish no earlier than 2006-12-15 | S5 | 2688h | 1881.6h |  | China Mobile |  | Rel-7 |  |  |
| 196 | 39.1.13 | Backward and Forward Compatibility of IRP systems | 336d? | 2005-09-02 A | 2006-12-15 | 25% | 252d? | 2005-09-02 | 2006-12-15 | 336d? | 410d | finish no earlier than 2006-12-15 | S5 | 2688h | 672h |  | Ericsson |  | Rel-7 |  |  |
| 197 | 39.1.14 | Repeater Network Resource Model (NRM) definition | 220d? | 2006-02-13 A | 2006-12-15 | 95% | 11d? | 2006-02-13 | 2006-12-15 | 220d? | 410d | start no earlier than 2006-02-13 | S5 | 1760h | 1672h |  | China Mobile |  | Rel-7 |  |  |
| 198 | 39.1.15 | UTRAN radio channel power monitoring | 220d? | 2006-02-13 A | 2006-12-15 | 65% | 77d? | 2006-02-13 | 2006-12-15 | 220d? | 410d | start no earlier than 2006-02-13 | S5 | 1760h | 1144h |  | China Mobile |  | Rel-7 |  |  |
| 199 | 39.2 | **Performance Management** | 336d? | 2005-09-02 A | 2006-12-15 | 68% | 106.63d? | 2005-09-02 | 2006-12-15 | 336d? | 410d |  | S5 | 20576h | 12211.2h | OAM7-PM |  |  | Rel-7 |  |  |
| 200 | 39.2.1 | Performance measurements definition for CN CS | 336d? | 2005-09-02 A | 2006-12-15 | 90% | 33.6d? | 2005-09-02 | 2006-12-15 | 336d? | 410d | finish no earlier than 2006-12-15 | S5 | 2688h | 2419.2h |  | China Mobile |  | Rel-7 |  |  |
| 201 | 39.2.2 | Enhancement UTRAN performance measurements definition | 336d? | 2005-09-02 A | 2006-12-15 | 80% | 67.2d? | 2005-09-02 | 2006-12-15 | 336d? | 410d | finish no earlier than 2006-12-15 | S5 | 2688h | 2150.4h |  | China Mobile |  | Rel-7 |  |  |
| 202 | 39.2.3 | Add TDD specific counters in Performance measurement | 336d? | 2005-09-02 A | 2006-12-15 A | 100% |  | 2005-09-02 | 2006-12-15 | 336d? |  | finish no earlier than 2006-12-15 | S5 | 2688h | 2688h |  | CATT |  | Rel-7 |  |  |
| 203 | 39.2.4 | ATM bearer network Performance measurements | 336d? | 2005-09-02 A | 2006-12-15 | 55% | 151.2d? | 2005-09-02 | 2006-12-15 | 336d? | 410d | finish no earlier than 2006-12-15 | S5 | 2688h | 1478.4h |  | ZTE |  | Rel-7 |  |  |
| 204 | 39.2.5 | IP bearer network Performance measurement definitions | 336d? | 2005-09-02 A | 2006-12-15 | 40% | 201.6d? | 2005-09-02 | 2006-12-15 | 336d? | 410d | finish no earlier than 2006-12-15 | S5 | 2688h | 1075.2h |  | China Mobile |  | Rel-7 |  |  |
| 205 | 39.2.6 | Performance measurements definition for IMS | 336d? | 2005-09-02 A | 2006-12-15 | 50% | 168d? | 2005-09-02 | 2006-12-15 | 336d? | 410d | finish no earlier than 2006-12-15 | S5 | 2688h | 1344h |  | China Mobile |  | Rel-7 |  |  |
| 206 | 39.2.7 | HSDPA performance measurements | 220d? | 2006-02-13 A | 2006-12-15 | 60% | 88d? | 2006-02-13 | 2006-12-15 | 220d? | 410d | start no earlier than 2006-02-13 | S5 | 1760h | 1056h |  | China Mobile |  | Rel-7 |  |  |

Notes:
- 184: Text3: 32.63x or New 3273x
- 185: Text3: TR 32.806, 32.101
- 186: Text3: new TS 32.yzx
- 187: Text3: new TR 32.8xy, new TSs 32.111-n,32.60n; For n = 1 to 5
- 188: Text3: 32.101,32.175, new TSs 32.161,32.307,32.317,32.607,32.617,32.667
- 189: Text3: new TSs 32.372,32.373,32.374; 32.111,32.30x,32.32x,32.33x,32.34x,32.35x,32.36x,32.41x,32.60x,32.61x,32.66x
- 190: Text3: new TSs 32.15w,32.15x,32.15y,32.15z; 32.150,32.151,32.152
- 191: Text3: new TR 32.8xy, new TSs 32.38x,32.60n,32.61n; For n = 1 to 5
- 192: Text3: new TR 32.8xy ; new TSs 32.111-n,32.30n; For n = 1 to 5
- 193: Text3: new TS 32.xxx, new TSs 32.62n,32.63n,32.64n,32.65n,32.71n,32.74n,32.69n; For n = 1 to 5
- 194: Text3: 32.62n; For n = 1 to 5
- 195: Text3: 32.74x
- 196: Text3: TR 32.805. new TS 32.15X
- 197: Text3: 32.64n; For n = 1 to 5
- 198: Text3: 32.405, 32.64n; For n = 1 to 5
- 200: Text3: 32.407, 32.408
- 201: Text3: 32.405
- 202: Text3: 32.405
- 203: Text3: 32.404,32.405,32.406,32.407
- 204: Text3: 32.404,32.405,32.406,32.407
- 205: Text3: 32.404,32.409,32.437, 32.632/3/4/5
- 206: Text3: 32.405

| ID | WBS | Task | Type | Duration | Start | Finish | Complete | Remaining | Baseline start | Baseline finish | Baseline duration | Total slack | Constraint | Resources | Work | Actual work | Text1 | Text4 | Text6 | Text7 | Text12 | Text5 | Text8 |
| --- | --- | --- | --- | --- | --- | --- | --- | --- | --- | --- | --- | --- | --- | --- | --- | --- | --- | --- | --- | --- | --- | --- | --- |
| 207 | 44.5 | **Trace Management** |  | 869d? | 2004-02-16 A | 2007-06-15 | 45% | 479.57d? | 2004-02-16 | 2006-12-15 | 740d? | 281d |  | S5 | 25498.2h | 9217.33h | OAM7-Trace | Vodafone | Rel-7 | TSG |  |  |  |
| 208 | 39.3.1 | Deleted - Trace Management for IMS (merged with 35062) |  | 420d? | 2005-05-09 A | 2006-12-15 A | 100% |  | 2005-05-09 | 2006-12-15 | 420d? |  | finish no earlier than 2006-12-15 | S5 | 3360h | 3360h |  | Nortel | Rel-7 | TSG | SP-31 |  |  |
| 209 | 39.3.2 | End-to-end Service Level tracing for IMS |  | 286d? | 2005-11-11 A | 2006-12-15 | 60% | 114.4d? | 2005-11-11 | 2006-12-15 | 286d? | 410d | finish no earlier than 2006-12-15 | S5 | 2288h | 1372.8h |  | Vodafone | Rel-7 | TSG |  |  |  |
| 210 | 39.3.3 | Trace record content for UTRAN TDD |  | 420d? | 2005-05-09 A | 2006-12-15 A | 100% |  | 2005-05-09 | 2006-12-15 | 420d? |  | finish no earlier than 2006-12-15 | S5 | 3360h | 3360h |  | CATT | Rel-7 | TSG |  |  |  |
| 211 | 39.3.4 | IRP for Subscriber and Equipment Trace Management |  | 336d? | 2005-09-02 A | 2006-12-15 | 25% | 252d? | 2005-09-02 | 2006-12-15 | 336d? | 410d | finish no earlier than 2006-12-15 | S5 | 2688h | 672h |  | Nokia | Rel-7 | TSG |  |  |  |
| 212 | 39.3.5 | SIP enhancements for trace |  | 862.14d? | 2004-02-16 A | 2007-06-15 | 2% | 844.9d? | 2004-02-16 | 2006-06-16 | 603.14d? | 281d | finish no earlier than 2007-06-15 | C1 | 6897.12h | 137.94h | OAM7-Trace-SIP |  | Rel-7 |  |  |  |  |
| 213 | 39.3.6 | Service Level Tracing in IMS |  | 179.14d? | 2006-09-22 A | 2007-06-08 | 5% | 170.18d? | 2004-02-16 | 2006-06-16 | 603.14d? | 285d | finish no earlier than 2006-10-11 | C1 | 1433.12h | 71.65h | OAM7-Trace-Serv | Jari Jansson, Nokia | Rel-7 |  |  | jari.jansson@nokia.com | Andrijana |
| 214 | 40 | Trust Requirements for Open Platforms in 3GPP |  | 499d? | 2005-01-03 A | 2006-11-30 | 55% | 224.55d? | 2005-01-03 | 2005-06-10 | 115d? | 421d | finish no earlier than 2006-11-30 | S3 | 3992h | 2195.6h | TrustOP | Silke Holtmanns, Nokia | Rel-7 | TSG |  | Silke.Holtmanns@NOKIA.COM | Michael |
| 215 | 41 | Development of UEA2 and UIA2 |  | 268d? | 2004-12-01 A | 2005-12-09 | 80% | 53.6d? | 2004-12-01 | 2005-12-09 | 268d? | 675d | finish no earlier than 2005-12-09 | S3 | 2144h | 1715.2h | AlgUEA2 | Per Christoffersson, Teliasonera | Rel-7 | TSG |  | per.christoffersson@teliasonera.com | Michael |
| 216 | 42 | Lawful Interception in the 3GPP Rel-7 architecture |  | 118d? | 2005-06-28 A | 2005-12-08 | 70% | 35.4d? | 2005-06-28 | 2005-12-08 | 118d? | 676d | start no earlier than 2005-06-28 | S3 | 944h | 660.8h | LI-7A | Berthold Wilhelm, BMWI | Rel-7 |  |  | berthold.wilhelm@regtp.de | Mike |
| 217 | 43 | **Support of Conversational Services in A/Gb mode via the PS domain** |  | 681d? | 2005-04-08 A | 2007-11-16 | 12% | 599.3d? | 2005-04-08 | 2006-12-19 | 442.05d? | 170d |  | GP | 18842.8h | 1836.21h | SCSAGB | Gunnar Hedby, Ericsson | Rel-7 |  |  | gunnar.hedby@ericsson.com | Paolo |
| 218 | 43.1 | Minimise the transfer delay between the SGSN and the MS |  | 659.95d? | 2005-04-08 A | 2007-11-16 | 20% | 527.96d? | 2005-04-08 | 2006-12-19 | 421d? | 170d | finish no earlier than 2007-11-16 | GP | 5279.6h | 1055.92h | SCSAGB-MTD |  | Rel-7 |  |  |  | Paolo |
| 219 | 43.2 | Definition of radio resource management functionality |  | 681d? | 2005-04-08 | 2007-11-16 |  |  | 2005-04-08 | 2006-11-17 | 421d? | 170d | finish no earlier than 2007-11-16 | G1 | 5448h |  | SCSAGB-RRM | Gunnar Hedby, Ericsson | Rel-7 |  |  | gunnar.hedby@ericsson.com | Paolo |
| 220 | 43.3 | Support of Conversational Services in A/Gb mode via the PS domain – RLC Non-Persistent mode |  | 361d? | 2006-06-30 A | 2007-11-16 | 20% | 288.8d? |  |  |  | 170d | finish no earlier than 2007-11-16 | G2 | 2888h | 577.6h | SCSAGB-RLCNP | Gunnar Hedby, Ericsson | Rel-7 |  |  | gunnar.hedby@ericsson.com | Gert |
| 221 | 43.4 | Deleted- Radio Channel Support | milestone | 0d? | 2006-07-17 A | 2006-07-17 A | 100% |  | 2005-04-08 | 2006-11-17 | 421d? |  | start no earlier than 2006-07-17 | G2 |  |  | SCSAGB-RCHS | Gunnar Hedby, Ericsson | Rel-7 |  | SP-32 | gunnar.hedby@ericsson.com | Gert |
| 222 | 43.5 | Deleted- Modifications to FLO | milestone | 0d? | 2006-07-17 A | 2006-07-17 A | 100% |  | 2005-04-08 | 2006-11-17 | 421d? |  | start no earlier than 2006-07-17 | G2 |  |  | SCSAGB-FLO | Gunnar Hedby, Ericsson | Rel-7 |  | SP-32 | gunnar.hedby@ericsson.com | Gert |
| 223 | 44 | **Addition of new frequency band to GSM (T-GSM810)** |  | 421d? | 2005-04-08 A | 2006-11-17 | 97% | 12.97d? | 2005-04-08 | 2006-06-30 | 321d? | 430d |  | GP | 8832h | 5295.6h | TGSM810 | Chen De, Huawei | Rel-7 |  |  | chende@huawei.com | Paolo |
| 224 | 44.1 | Changes to core specification |  | 106d? | 2005-04-08 A | 2005-09-02 A | 100% |  | 2005-04-08 | 2005-09-02 | 106d? |  | finish no earlier than 2005-09-02 | GP | 848h | 848h | TGSM810-Core | Chen De, Huawei | Rel-7 |  |  | chende@huawei.com | Paolo |
| 225 | 44.2 | Changes to MS testing specification |  | 421d? | 2005-04-08 A | 2006-11-17 | 95% | 21.05d? | 2005-04-08 | 2006-06-30 | 321d? | 430d | finish no earlier than 2006-11-17 | G3 | 3368h | 3199.6h | TGSM810-MStest | Chen De, Huawei | Rel-7 |  |  | chende@huawei.com | Stoyan |
| 226 | 44.3 | Changes to BTS testing specification |  | 156d? | 2005-04-08 A | 2005-11-11 A | 100% |  | 2005-04-08 | 2005-11-11 | 156d? |  | finish no earlier than 2005-11-11 | G1 | 1248h | 1248h | TGSM810-BTStest | Chen De, Huawei | Rel-7 |  |  | chende@huawei.com | Paolo |
| 227 | 45 | **Handover of dedicated and shared resources while in dual transfer mode** |  | 421d? | 2005-04-08 A | 2006-11-17 A | 100% |  | 2005-04-08 | 2006-11-17 | 421d? |  |  | GP | 12672h | 12672h | HODSRDTM | Rami Vaittinen, Nokia | Rel-7 |  |  | rami.vaittinen@nokia.com | Paolo |
| 228 | 45.1 | Handover of dedicated and shared resources while in dual transfer mode |  | 321d? | 2005-04-08 A | 2006-06-30 A | 100% |  | 2005-04-08 | 2006-06-30 | 321d? |  | finish no earlier than 2006-06-30 | G2 | 2568h | 2568h | HODSRDTM-G2 | Rami Vaittinen, Nokia | Rel-7 |  |  | rami.vaittinen@nokia.com | Gert |
| 229 | 45.2 | MS Conformance Testing |  | 421d? | 2005-04-08 A | 2006-11-17 A | 100% |  | 2005-04-08 | 2006-11-17 | 421d? |  | finish no earlier than 2006-11-17 | G3 | 3368h | 3368h | HODSRDTM-Mstest | Rami Vaittinen, Nokia | Rel-7 |  |  | rami.vaittinen@nokia.com | Stoyan |
| 230 | 45.3 | BTS conformance testing |  | 421d? | 2005-04-08 A | 2006-11-17 A | 100% |  | 2005-04-08 | 2006-11-17 | 421d? |  | finish no earlier than 2006-11-17 | G1 | 3368h | 3368h | HODSRDTM-BTStest | Rami Vaittinen, Nokia | Rel-7 |  |  | rami.vaittinen@nokia.com | Paolo |
| 231 | 46 | Future GERAN Evolution |  | 421d? | 2005-04-08 A | 2006-11-17 | 90% | 42.1d? | 2005-04-08 | 2006-06-30 | 321d? | 430d | finish no earlier than 2006-11-17 | GP | 3368h | 3031.2h | FGE | Eddie Riddington, Nokia Corporation | Rel-7 |  |  | eddie.riddington@nokia.com | Paolo |
| 232 | 47 | 3G-324M Video Telephony Call Setup Times Improvements |  | 341d? | 2005-06-08 A | 2006-09-27 A | 100% |  | 2005-06-08 | 2006-09-27 | 341d? |  | finish no earlier than 2006-09-27 | S4 | 2728h | 2728h | VTCSTI | Edward Hall (Vodafone) | Rel-7 |  |  | edward.hall@vodafone.co.uk | Paolo |

Notes:
- 208: Text3: 32.421,32.422,32.423
- 209: 07/2005: OMA (Stage 1), Stage 2/3 SA5, CT1/3/4 / Text3: 32.101,32.421,32.422,32.423
- 210: Text3: 32.421,32.422,32.423
- 211: Text3: 32.421,32.422,32.423. 3 new TS 32.4x1,2,3
- 213: Text3: 24.229, 24.167, 29.228,29.229,29.163,29.332
- 214: WID approved SA#26. Record created after SA#27 / Text3: 33.905
- 215: WID approved SA#26, Dependant on Funding Availability. Record created after SA#27 / Text3: 35.919, 35.215, 35.216, 35.217, 35.218
- 216: Text3: 33.106, 33.107, 33.108
- 217: Originally started Nov. 2003 as GP-030443
- 220: Text3: 43.955, 43.064, 44.060, 45.001, 45.002, 45.003, 45.005, 45.010, 51.010, 51.021
- 223: Text3: 45.005, 45.050, 24.008, 45.008, 45.001, 43.022, 43.030, 44.018, 44.060, 51.010-1, 51.021
- 224: Text3: 45.005, 45.050, 24.008, 45.008, 45.001, 43.022, 43.030, 44.018, 44.060
- 225: Started / Text3: 51010-1
- 226: Text3: 51021
- 227: Started at GERAN#24
- 228: Started at GERAN#24 / Text3: 43.055, 44.018, 44.060
- 229: Stopped, no work done / Text3: 51-010
- 230: Stopped, no work done / Text3: 51.026
- 231: Text3: 45.912
- 232: Text3: 26.911

| ID | WBS | Task | Type | Duration | Start | Finish | Complete | Remaining | Baseline start | Baseline finish | Baseline duration | Total slack | Constraint | Resources | Work | Actual work | Text1 | Text3 | Text4 | Text5 | Text6 | Text8 | Text7 | Text12 |
| --- | --- | --- | --- | --- | --- | --- | --- | --- | --- | --- | --- | --- | --- | --- | --- | --- | --- | --- | --- | --- | --- | --- | --- | --- |
| 233 | 48 | **Identification of Communication Services in IMS** |  | 489d? | 2005-05-02 A | 2007-03-15 | 47% | 260.33d? | 2005-05-02 | 2006-12-15 | 425d? | 346d |  | S2 | 10408h | 3165.76h | ServID | 22.228, 23.228, 23.203, 32.260, 32.298, 32.299 | Stephen Terrill, Ericsson | stephen.terrill@ericsson.com | Rel-7 | Maurice |  |  |
| 234 | 48.1 | TR for ICS |  | 232d? | 2005-05-02 A | 2006-03-21 A | 100% |  | 2005-05-02 | 2006-03-21 | 232d? |  | finish no earlier than 2006-03-20 | S2 | 1856h | 1856h |  | 23.816 |  |  | Rel-7 |  |  |  |
| 235 | 48.2 | Stage 2 of ICS |  | 144d? | 2005-11-11 A | 2006-05-31 A | 100% |  | 2005-11-11 | 2006-05-31 | 144d? |  | start no earlier than 2005-11-11 | S2 | 1152h | 1152h |  |  |  |  | Rel-7 |  |  |  |
| 236 | 48.3 | Stage 3 of ICS |  | 250d? | 2006-03-31 A | 2007-03-15 | 1% | 246.28d? | 2006-03-31 | 2006-12-15 | 186d? | 346d | finish no earlier than 2007-03-15 | C1 | 2000h | 29.76h |  |  | Christer Holmberg (Ericsson) | christer.holmberg@ericsson.com | Rel-7 | Andrijana |  |  |
| 237 | 48.4 | SA5 Charging aspects of ServID |  | 186d? | 2006-03-31 | 2006-12-15 |  |  | 2006-03-31 | 2006-12-15 | 186d? | 410d | finish no earlier than 2006-12-15 | S5 | 1488h |  | ServID-CH | 32.260, 32.298, 32.299 | Orange | alain.bibas@orange-ft.com | Rel-7 | Adrian |  |  |
| 238 | 49 | **VoIMS bearer related enhancements** |  | 354d? | 2005-03-15 A | 2006-07-21 | 99% | 0d? | 2005-03-15 | 2006-07-21 | 354d? | 0d |  | S2 | 4303.2h | 1576h | VoIMS |  |  |  | Rel-7 |  |  |  |
| 239 | 49.1 | Improved support of IMS Realtime Services using HSDPA/HSUPA |  | 197d? | 2005-03-15 A | 2005-12-14 A | 100% |  | 2005-03-15 | 2005-12-14 | 197d? |  | start no earlier than 2005-03-15 | R2 | 1576h | 1576h | RANimp-IMSRealTime |  | Don Zelmer | don.zelmer@CINGULAR.COM | Rel-7 | MCC_RAN | TSG |  |
| 240 | 49.2 | Deleted - FS on enhancement of radio performance for VoIMS | milestone | 0d? | 2006-07-21 A | 2006-07-21 A | 100% |  | 2006-07-21 | 2006-07-21 | 0d? |  | start no earlier than 2006-07-21 | S2 |  |  | VoIMS | 23.807 | Laurence Lautier, Nortel Networks | lautierl@nortel.com | Rel-7 | Maurice |  | SP-32 |
| 241 | 50 | Performance Characterization of VoIMS over HSDPA\EUL channels |  | 523d? | 2005-03-15 A | 2007-03-15 | 30% | 366.1d? | 2005-03-15 | 2006-12-07 | 453d? | 346d | finish no earlier than 2007-03-15 | S4 | 4184h | 1255.2h | VoIMS-PCVoIMS | 26.935 | Dimitris Vasilaras (Lucent Technologies) | dvasilaras@lucent.com | Rel-7 | Paolo | TSG |  |
| 242 | 51 | **Optimizations for Multimedia Telephony over IMS** |  | 312d? | 2005-09-28 A | 2006-12-07 | 55% | 140.4d? | 2005-09-28 | 2006-12-07 | 312d? | 416d |  | S4 | 4992h | 2103.6h | OMTIMS | 26.235, 26.236 | Olle Franceschi (Ericsson) | olle.franceschi@ericsson.com | Rel-7 | Paolo |  |  |
| 243 | 51.1 | Characterisation of Adaptive Jitter Management Performance for VoIP Services |  | 312d? | 2005-09-28 A | 2006-12-07 | 55% | 140.4d? | 2005-09-28 | 2006-12-07 | 312d? | 416d | finish no earlier than 2006-12-07 | S4 | 2496h | 1372.8h | OMTIMS-CAJMP |  | David Huo (Lucent Technologies) | dhuo@lucent.com | Rel-7 | Paolo |  |  |
| 244 | 52 | End-to-End Multimedia Services Performance Metrics |  | 312d? | 2005-09-28 A | 2006-12-07 | 25% | 234d? | 2005-09-28 | 2006-12-07 | 312d? | 416d | finish no earlier than 2006-12-07 | S4 | 2496h | 624h | E2EMSPM |  | Zhang Yan (China Mobile) | zhangyanyf@chinamobile.com | Rel-7 | Paolo |  |  |
| 245 | 53 | **Supporting Globally Routable User Agent URIs in IMS** |  | 280d? | 2005-11-14 A | 2006-12-08 | 84% | 45.33d? | 2005-11-14 | 2006-09-15 | 220d? | 415d |  | S2 | 3440h | 2816h | GRUU | 23.8XX, 22.228, 23.228, 23.218, 24.229 | Adrian Buckley (Research In Motion) | abuckley@rim.com | Rel-7 | Maurice |  |  |
| 246 | 53.1 | TR on GRUU |  | 219d? | 2005-11-14 A | 2006-09-14 A | 100% |  | 2005-11-14 | 2006-09-14 | 219d? |  | finish no earlier than 2006-09-14 | S2 | 1752h | 1752h |  |  |  |  | Rel-7 | Maurice |  |  |
| 247 | 53.2 | Stage 2 of GRUU |  | 65d? | 2006-07-03 A | 2006-09-29 A | 100% |  | 2006-06-26 | 2006-09-15 | 60d? |  | start no earlier than 2006-07-03 | S2 | 520h | 520h |  |  |  |  | Rel-7 | Maurice |  |  |
| 248 | 53.3 | Stage 3 of GRUU |  | 136d? | 2006-06-02 A | 2006-12-08 | 50% | 68d? | 2006-06-26 | 2006-09-15 | 60d? | 415d | finish no earlier than 2006-12-08 | C1 | 1088h | 544h |  |  | Bernie McKibben, CableLabs |  | Rel-7 | Andrijana |  |  |
| 249 | 54 | ISIM API for Java Card |  | 200d? | 2005-03-14 A | 2005-12-16 | 90% | 20d? | 2005-03-14 | 2005-12-16 | 200d? | 670d | finish no earlier than 2005-12-16 | C6 | 1600h | 1440h | APIJAVA | 31.103, TS 102 241 | Sebastian Hans, Sun Microsystems Ltd. |  | Rel-7 | Gaby |  |  |
| 250 | 55 | **Rel7 Security enhancements** |  | 319d? | 2005-09-12 A | 2006-11-30 | 86% | 43.96d? | 2005-09-12 | 2006-08-14 | 241d? | 421d |  | S3 | 9336h | 7167.11h | SEC7 |  |  |  | Rel-7 |  |  |  |
| 251 | 55.1 | HTTPS connection between a UICC and a NAF |  | 1d? | 2005-09-12 A | 2005-09-12 A | 100% |  | 2005-09-12 | 2005-09-12 | 1d? |  | start no earlier than 2005-09-12 | S3 | 8h | 8h | SEC7-HSUN | 33.222, 24.109, 33.918 | Jacques Seif (Axlato) | JSeif@axalto.com | Rel-7 |  |  |  |
| 252 | 55.2 | 2G GBA: 2G SIM usage in 3GPP GAA framework |  | 61d? | 2005-09-12 A | 2005-12-05 A | 100% |  | 2005-09-12 | 2005-12-05 | 61d? |  | finish no earlier than 2005-12-05 | S3 | 488h | 488h | SEC7-2GGBA | 33.220, 33.920 | Silke Holtmanns (Nokia) | Silke.Holtmanns@nokia.com | Rel-7 |  |  |  |
| 253 | 55.3 | Generic Authentication Architecture usage extensions and optimisations |  | 319d? | 2005-09-12 A | 2006-11-30 | 75% | 79.75d? | 2005-09-12 | 2005-09-12 | 1d? | 421d | finish no earlier than 2006-11-30 | S3 | 2552h | 1914h | GAA2 | 33.220, 29.109, 33.223 | Silke Holtmanns (Nokia) | Silke.Holtmanns@nokia.com | Rel-7 |  |  |  |
| 254 | 55.4 | **SS7 TCAP security Gateway** |  | 241d? | 2005-09-12 A | 2006-08-14 | 98% | 4.16d? | 2005-09-12 | 2006-08-14 | 241d? | 499d |  | S3 | 3736h | 2556.8h | SEC7-NDS-TCAPsec | 33.200, 33.204 | Marc Blommaert (Siemens) | marc.blommaert@siemens.com | Rel-7 |  |  |  |
| 255 | 55.4.1 | SA3 aspects of SEC7-NDS-TCAPsec |  | 130d? | 2005-09-12 A | 2006-03-10 | 97% | 3.9d? | 2005-09-12 | 2006-03-10 | 130d? | 610d | finish no earlier than 2006-03-10 | S3 | 1040h | 1008.8h | SEC7-NDS-TCAPsec-SA3 | 33.200, 33.204 | Marc Blommaert (Siemens) | marc.blommaert@siemens.com | Rel-7 |  |  |  |
| 256 | 55.4.2 | TCAPsec Gateway |  | 96d? | 2006-04-03 A | 2006-08-14 A | 100% |  | 2006-04-03 | 2006-08-14 | 96d? |  | start no earlier than 2006-04-01 | C4 | 768h | 768h | SEC7-NDS-TCAPsec-CT4 | new TS 29.204 | Ulrich Wiehe, Siemens | Ulrich.wiehe@gksag.de | Rel-7 | Kimmo |  |  |
| 257 | 56 | Network Composition |  | 211d? | 2005-12-07 A | 2006-09-27 | 50% | 105.5d? | 2005-12-07 | 2006-09-27 | 211d? | 467d | finish no earlier than 2006-09-27 | S1 | 1688h | 844h | NetComp | 22.980 | Joerg Swetina (Siemens) | joerg.swetina@siemens.com | Rel-7 |  |  |  |
| 258 | 57 | Key establishment between a UICC and a terminal |  | 201.45d? | 2005-12-07 A | 2006-09-28 | 70% | 60.44d? | 2005-12-07 | 2006-09-28 | 201.45d? | 466d | finish no earlier than 2006-09-28 | S3 | 1611.6h | 1128.12h | KeyEstUTerm | 33.110 | Mireille Pauliac (Gemplus) | mireille.pauliac@gemplus.com | Rel-7 |  |  |  |

Notes:
- 233: WID approved SA#28. Updated WID approved SA#32
- 236: end date updated by CT1-chairman after CT#33
- 237: 03/2006 SA#31 WID approved
- 238: Created by MCC to group all VoIMS related items, after consultation of chairs
- 240: WID approved SA#28: SA2#52: CLOSED - To be removed from the work plan
- 245: Approved at SP#29
- 246: Abandomned
- 247: S2#52: "GURU" corrected to "GRUU"
- 248: S2#52: "GURU" corrected to "GRUU"
- 256: Study WI...

| ID | WBS | Task | Duration | Start | Finish | Complete | Remaining | Baseline start | Baseline finish | Baseline duration | Total slack | Constraint | Resources | Work | Actual work | Text1 | Text3 | Text4 | Text5 | Text6 | Text8 | Text7 |
| --- | --- | --- | --- | --- | --- | --- | --- | --- | --- | --- | --- | --- | --- | --- | --- | --- | --- | --- | --- | --- | --- | --- |
| 259 | 58 | **Mobile Station Receive Diversity (DARP Phase II)** | 331d? | 2005-11-11 A | 2007-02-16 | 29% | 234.38d? | 2005-11-11 | 2007-01-19 | 311d? | 365d |  | GP | 13080h | 3268.51h | MSRD2 | 24.008, 45.005, 51.010 | Kent Pedersen, Nokia Corporation (ETSI) | kent.pedersen@nokia.com | Rel-7 | Paolo |  |
| 260 | 58.1 | MS conformance test of DARP Phase II (MSRD) | 311d? | 2005-11-11 | 2007-01-19 |  |  | 2005-11-11 | 2007-01-19 | 311d? | 385d | finish no earlier than 2007-01-19 | GP | 2488h |  | MSRD2-Msconf | 51.010 | Kent Pedersen, Nokia Corporation (ETSI) | kent.pedersen@nokia.com | Rel-7 | Paolo, Stoyan |  |
| 261 | 58.2 | Performance Requirements for Mobile Station Receive Diversity, DARP Phase II | 331d? | 2005-11-11 A | 2007-02-16 | 25% | 248.25d? | 2005-11-11 | 2006-09-08 | 216d? | 365d | finish no earlier than 2007-02-16 | GP | 2648h | 662h | MSRD2-PerfReq | 45.005 | Kent Pedersen, Nokia Corporation (ETSI) | kent.pedersen@nokia.com | Rel-7 | Paolo |  |
| 262 | 58.3 | Capability signalling of Mobile Station Receive Diversity, DARP Phase II | 331d? | 2005-11-11 | 2007-02-16 |  |  | 2005-11-11 | 2006-09-08 | 216d? | 365d | finish no earlier than 2007-02-16 | GP | 2648h |  | MSRD2-CapSig | 24.008 | Kent Pedersen, Nokia Corporation (ETSI) | kent.pedersen@nokia.com | Rel-7 | Paolo, Gert |  |
| 263 | 58.4 | Test Scenarios for Mobile Station Receive Diversity, DARP Phase II | 331d? | 2005-11-11 A | 2007-02-16 | 90% | 33.1d? | 2005-11-11 | 2007-01-19 | 311d? | 365d | finish no earlier than 2007-02-16 | GP | 2648h | 2383.2h | MSRD2-TestSc | 45.005 | Kent Pedersen, Nokia Corporation (ETSI) | kent.pedersen@nokia.com | Rel-7 | Paolo |  |
| 264 | 59 | MBMS Enhancements | 109d? | 2005-07-11 A | 2005-12-08 | 75% | 27.25d? | 2005-07-11 | 2005-12-08 | 109d? | 676d | finish no earlier than 2005-12-08 | S1 | 872h | 654h | MBMSE |  | Liu Hong, China Mobile | liuhongyfw@chinamobile.com | Rel-7 | Mike |  |
| 265 | 60 | MBMS User Service Extensions | 392d? | 2005-12-07 A | 2007-06-07 | 25% | 294d? | 2005-12-07 | 2006-12-07 | 262d? | 286d | finish no earlier than 2007-06-07 | S4 | 3136h | 784h | MBMSUSE | 26.346, 26.946 | Thorsten Lohmar (Ericsson) | Thorsten.Lohmar@ericsson.com | Rel-7 | Paolo |  |
| 266 | 61 | IMS Support of Conferencing and Messaging Group Management | 354d? | 2005-11-04 A | 2007-03-15 | 25% | 265.5d? | 2005-11-04 | 2006-09-08 | 221d? | 347d | finish no earlier than 2007-03-15 | C1 | 2832h | 708h | IMSconf |  | Keith Drage (Lucent) | drage@lucent.com | Rel-7 | Andrijana |  |
| 267 | 62 | **Selective Disabling of UE Capabilities** | 489.36d? | 2005-01-24 A | 2006-12-08 | 91% | 43.06d? | 2005-01-24 | 2006-12-08 | 489.36d? | 415d |  | S1 | 9636.8h | 8788.82h | SDoUE | 22.xxx | Nigel Barnes (Motorola Ltd) | Nigel.Barnes@motorola.com | Rel-7 | Michael | TSG |
| 268 | 62.1 | Stage 1 of SDoUE | 393.6d? | 2005-01-24 A | 2006-12-08 A | 100% |  | 2005-01-24 | 2006-12-08 | 393.6d? |  | finish no earlier than 2006-12-08 | S1 | 3148.8h | 3148.8h | SDoUE-CRs | 22.011, 22.060, 23.060, 24.008, 23.805, 24.305 | Nigel Barnes (Motorola Ltd) | Nigel.Barnes@motorola.com | Rel-7 | Michael | TSG |
| 269 | 62.2 | TR on different possible architectures | 195d? | 2005-03-21 A | 2005-12-16 A | 100% |  | 2005-03-21 | 2005-12-16 | 195d? |  | finish no earlier than 2005-12-16 | S2 | 1560h | 1560h |  | 23.805 |  |  | Rel-7 | Maurice |  |
| 270 | 62.3 | Stage 3 of SDoUE | 166d? | 2006-03-10 A | 2006-10-30 | 60% | 66.4d? | 2006-03-10 | 2006-09-08 | 131d? | 445d | finish no earlier than 2006-10-30 | C1 | 1328h | 796.8h |  | New TS 24.305 | Christian Herrero (Ericsson) | christian.herrero@ericsson.com | Rel-7 | Andrijana |  |
| 271 | 63 | **Personal Network Management (PNM)** | 276d? | 2005-07-11 A | 2006-07-31 | 91% | 25.79d? | 2005-07-11 | 2006-07-31 | 276d? | 509d |  | S1 | 5689.6h | 5157.88h | PNPAN |  | Armin Toepfer, Vodafone | armin.toepfer@vodafone.com | Rel-7 | Mike |  |
| 272 | 63.1 | Study of PNPAM | 167d? | 2005-07-11 A | 2006-02-28 A | 100% |  | 2005-07-11 | 2006-02-28 | 167d? |  | start no earlier than 2005-07-11 | S1 | 1336h | 1336h |  |  |  |  | Rel-7 |  |  |
| 273 | 63.2 | Stage 1 of PNPAM | 276d? | 2005-07-11 A | 2006-07-31 | 85% | 41.4d? | 2005-07-11 | 2006-07-31 | 276d? | 509d | start no earlier than 2005-07-11 | S1 | 2208h | 1876.8h |  | 22.259, 23.818 |  |  | Rel-7 |  |  |
| 274 | 64 | **Multimedia Telephony Service for IMS** | 265d? | 2006-03-10 A | 2007-03-15 | 51% | 131.17d? | 2006-03-15 | 2007-03-15 | 262d? | 346d |  | S1 | 7832h | 2904.8h | MTSI |  | Peter Bleckert, Ericsson | peter.bleckert @ericsson.com | Rel-7 | Mike |  |
| 275 | 64.1 | Stage 1 of MTSI | 191d? | 2006-03-15 A | 2006-12-06 A | 100% |  | 2006-03-15 | 2006-12-06 | 191d? |  | start no earlier than 2006-03-15 | S1 | 1528h | 1528h | MTSI-REQ | 22.173 | Peter Bleckert, Ericsson | peter.bleckert @ericsson.com | Rel-7 | Mike |  |
| 276 | 64.2 | Stage 3 of MTSI | 264d? | 2006-03-10 A | 2007-03-15 | 40% | 158.4d? | 2006-03-10 | 2006-09-08 | 131d? | 347d | finish no earlier than 2007-03-15 | C1 | 2112h | 844.8h |  | New TS 24.173 | Christer Holmberg (Ericsson) | christer.holmberg@ericsson.com | Rel-7 | Andrijana |  |
| 277 | 64.3 | Media handling and interaction in MTSI | 262d? | 2006-03-15 A | 2007-03-15 | 25% | 196.5d? | 2006-03-15 | 2007-03-15 | 262d? | 346d | finish no earlier than 2007-03-15 | S4 | 2096h | 524h | MTSI-MHI | 26.114, 26.235, 26.236 | Olle Franceschi, Ericsson | olle.franceschi@ericsson.com | Rel-7 | Paolo |  |
| 278 | 65 | **Multimedia interworking between IMS and CS networks** | 381d? | 2005-09-23 A | 2007-03-09 | 65% | 135.03d? | 2005-09-23 | 2006-06-02 | 181d? | 350d |  | C3 | 6487.99h | 2264.23h | MIW-IMS | 29.163 | Nico Gabriele, Vodafone UK | nico.gabriele@vodafone.com | Rel-7 | Seung Don |  |
| 279 | 65.1 | Note: Stages 1 and 2 defined in earlier Release | 49d? | 2005-09-23 A | 2005-11-30 A | 100% |  | 2005-09-23 | 2005-11-30 | 49d? |  | start no earlier than 2005-09-23 | S2 | 392h | 392h |  |  |  |  | Rel-7 |  |  |
| 280 | 65.2 | Stage 3 of MW-IMS | 381d? | 2005-09-23 A | 2007-03-09 | 60% | 152.4d? | 2005-09-23 | 2006-06-02 | 181d? | 350d | finish no earlier than 2007-03-09 | C3 | 3048h | 1828.8h |  | 29.163 |  |  | Rel-7 |  |  |
| 281 | 66 | **Network selection enhancements** | 192d? | 2006-03-15 A | 2006-12-07 | 76% | 47.03d? | 2006-03-15 | 2006-12-06 | 191d? | 416d |  | S1 | 4144h | 2613.2h | NSP-CR | 22.101, 22.011, 23.122, 24.008, 25.304, 31.102, 45.008 | Chris Friel, O2 | chris.friel@o2.com | Rel-7 | Michael |  |
| 282 | 66.1 | Stage 1 of NSP | 191d? | 2006-03-15 A | 2006-12-06 | 90% | 19.1d? |  |  |  | 417d | start no earlier than 2006-03-15 | S1 | 1528h | 1375.2h | NSP-TS | 22.101, 22.011, 23.122, 24.008, 25.304, 31.102, 45.008 | Chris Friel, O2 | chris.friel@o2.com | Rel-7 | Michael |  |
| 283 | 66.2 | Procedural aspects of NSP | 135d? | 2006-06-02 A | 2006-12-07 | 55% | 60.75d? |  |  |  | 416d | finish no earlier than 2006-12-07 | C1 | 1080h | 594h |  | 23.122, 24.008, 31.102 | Andrew Howell (Motorola) | andrew.howell@motorola.com | Rel-7 | Andrijana |  |

Notes:
- 259: Started
- 267: Moved from FS section Feb 06
- 268: Moved from FS section Feb 06
- 269: Moved from FS section Feb 06
- 271: Moved from FS section Feb 06. SP-33: Create new section to capture the PNM stage 2 aspects and identify any impacts to existing stage 2 specifications. S2 added as secondary responsibility
- 272: Moved from FS section Feb 06
- 273: Moved from FS section Feb 06: SP-33: Create new section to capture the PNM stage 2 aspects and identify any impacts to existing stage 2 specifications.
- 276: TS 24.173:IMS Multimedia telephony service and supplementary services
- 278: Moved from FS section Feb 06
- 279: Moved from FS section Feb 06

| ID | WBS | Task | Duration | Start | Finish | Complete | Remaining | Baseline start | Baseline finish | Baseline duration | Total slack | Constraint | Resources | Work | Actual work | Text1 | Text4 | Text5 | Text6 | Text8 | Text7 |
| --- | --- | --- | --- | --- | --- | --- | --- | --- | --- | --- | --- | --- | --- | --- | --- | --- | --- | --- | --- | --- | --- |
| 284 | 67 | **Interoperability between VGCS/VBS and A/Gb flexibility** | 183d? | 2006-03-22 A | 2006-12-01 | 77% | 42.78d? | 2006-03-22 | 2006-09-22 | 133d? | 420d |  | C1 | 4200h | 3218.16h | VGCSFlex | Robert Zaus (Siemens) | robert.zaus@siemens.com | Rel-7 | Andrijana |  |
| 285 | 67.1 | CT1 aspects of VGCSFlex | 159d? | 2006-03-22 A | 2006-10-30 | 90% | 15.9d? | 2006-03-22 | 2006-09-22 | 133d? | 444d | finish no earlier than 2006-10-30 | C1 | 1272h | 1144.8h |  |  |  | Rel-7 |  |  |
| 286 | 67.2 | CT4 aspects of VGCSFlex | 183d? | 2006-03-22 A | 2006-12-01 | 65% | 64.05d? | 2006-03-22 | 2006-09-22 | 133d? | 420d | finish no earlier than 2006-12-01 | C4 | 1464h | 951.6h |  |  |  | Rel-7 |  |  |
| 287 | 68 | **One Tunnel solution for Optimisation of Packet Data Traffic** | 190d? | 2006-03-27 A | 2006-12-15 | 64% | 68.2d? | 2006-03-27 | 2006-12-15 | 190d? | 410d |  | S2 | 3080h | 1974.36h | OPTUNEL | Antti Pasanen (Nokia) |  | Rel-7 | Maurice |  |
| 288 | 68.1 | Stage 2 Study for One Tunnel solution | 125d? | 2006-03-27 A | 2006-09-15 A | 100% |  | 2006-03-27 | 2006-09-15 | 125d? |  | finish no earlier than 2005-09-12 | S2 | 1000h | 1000h | OPTUNEL-Study | Antti Pasanen (Nokia) |  | Rel-7 | Maurice | TSG |
| 289 | 68.2 | Stage 2 specification for One Tunnel solution | 70d? | 2006-09-11 | 2006-12-15 |  |  | 2006-09-11 | 2006-12-15 | 70d? | 410d | finish no earlier than 2006-12-15 | S2 | 560h |  | OPTUNEL-Stage2 | Antti Pasanen (Nokia) |  | Rel-7 | Maurice | TSG |
| 290 | 69 | **Downlink Dual Carrier** | 346d? | 2006-01-20 A | 2007-05-18 | 25% | 259.24d? | 2006-01-20 | 2007-05-18 | 346d? | 300d |  | GP | 9920h | 1792h | GDCDL | Leonardo Provvedi, Siemens AG | leonardo.provvedi@roke.co.uk | Rel-7 | Paolo |  |
| 291 | 69.1 | Downlink Dual Carrier Stage 2 | 116d? | 2006-01-20 A | 2006-06-30 A | 100% |  | 2006-01-20 | 2006-06-30 | 116d? |  | finish no earlier than 2006-06-30 | G1 | 928h | 928h | GDCDL-Stage2 | Leonardo Provvedi, Siemens AG | leonardo.provvedi@roke.co.uk | Rel-7 | Paolo |  |
| 292 | 69.2 | Downlink Dual Carrier Stage 3 | 216d? | 2006-01-20 A | 2006-11-17 | 25% | 162d? | 2006-01-20 | 2006-11-17 | 216d? | 430d | start no earlier than 2006-01-20 | G2;; G1 | 3456h | 864h | GDCDL-Stage3 | Leonardo Provvedi, Siemens AG | leonardo.provvedi@roke.co.uk | Rel-7 | Gert, Paolo |  |
| 293 | 69.3 | Downlink Dual Carrier – MS Conformance Test | 346d? | 2006-01-20 | 2007-05-18 |  |  | 2006-01-20 | 2007-05-18 | 346d? | 300d | start no earlier than 2006-01-20 | G3 | 2768h |  | GDCDL-MStest | Leonardo Provvedi, Siemens AG | leonardo.provvedi@roke.co.uk | Rel-7 | Stoyan |  |
| 294 | 70 | Support of SIGTRAN in GERAN | 116d? | 2006-01-20 A | 2006-06-30 A | 100% |  | 2006-01-20 | 2006-06-30 | 116d? |  | finish no earlier than 2006-06-30 | GP | 928h | 928h | GSIGT | Peter Ostrup, Ericsson | peter.ostrup@ericsson.com | Rel-7 | Paolo |  |
| 295 | 71 | Packet Switched Streaming Enhancements | 261d? | 2006-06-08 A | 2007-06-07 | 10% | 234.9d? | 2006-01-20 | 2006-06-30 | 116d? | 286d | finish no earlier than 2007-06-07 | S4 | 2088h | 208.8h | PSSe | Olle Franceschi (Ericsson) | olle.franceschi@ericsson.com | Rel-7 | Paolo |  |
| 296 | 72 | **Charging Management small Enhancements** | 150d? | 2006-05-22 A | 2006-12-15 | 20% | 119.78d? |  |  |  | 410d |  | S5 | 2808h | 565.79h | CH7 | Orange | alain.bibas@francetelecom.com | Rel-7 | Adrian |  |
| 297 | 72.1 | Alternate Charged Party (ACP) for IMS | 150d? | 2006-05-22 A | 2006-12-15 | 10% | 135d? |  |  |  | 410d | start no earlier than 2006-05-22 | S5 | 1200h | 120h | CH7-IMS-ACP | Lucent | njmazzarella@lucent.com | Rel-7 |  |  |
| 298 | 72.2 | Align 3GPP Charging with OMA PoC Enabler Release 2.0 | 51d? | 2006-09-28 A | 2006-12-07 | 50% | 25.5d? |  |  |  | 416d | finish no earlier than 2006-12-07 | S5 | 408h | 204h | CH7-PoC | Siemens | gerald.goermer@siemens.com | Rel-7 | Adrian |  |
| 299 | 73 | **Latency Reductions** | 361d? | 2006-06-30 A | 2007-11-16 | 10% | 324.9d? |  |  |  | 170d |  | GP | 7624h | 473.6h | LATRED | Håkan Persson, Ericsson | Hakan.Persson@Ericsson.com | Rel-7 | Paolo |  |
| 300 | 73.1 | Improved Ack/Nack reporting | 361d? | 2006-06-30 A | 2007-11-16 | 10% | 324.9d? |  |  |  | 170d | finish no earlier than 2007-11-16 | G2 | 2888h | 288.8h | LATRED-ACKNAR | Håkan Persson, Ericsson | Hakan.Persson@Ericsson.com | Rel-7 | Gert |  |
| 301 | 73.2 | Reduced TTI | 231d? | 2006-06-30 A | 2007-05-18 | 10% | 207.9d? |  |  |  | 300d | finish no earlier than 2007-05-18 | G2 | 1848h | 184.8h | LATRED-REDTTI | Håkan Persson, Ericsson | Hakan.Persson@Ericsson.com | Rel-7 | Gert |  |
| 302 | 74 | PS Handover between GERAN/UTRAN mode and GAN Mode | 166d? | 2006-06-30 A | 2007-02-16 | 30% | 116.2d? |  |  |  | 365d | finish no earlier than 2007-02-16 | G2 | 1328h | 398.4h | GUGAN | John Diachina, Ericsson | John.Diachina@Ericsson.com | Rel-7 | Gert |  |
| 303 | 75 | CSI Terminating Session handling | 126d? | 2006-06-08 A | 2006-11-30 | 52% | 60.48d? |  |  |  | 421d | finish no earlier than 2006-11-30 | S2 | 1008h | 524.16h | CSItermS | Osok Song (Samsung) |  | Rel-7 | Maurice |  |
| 304 | 76 | High speed interface between the UICC and the ME | 121d? | 2006-09-22 A | 2007-03-09 | 5% | 114.95d? |  |  |  | 350d | start no earlier than 2006-09-22 | C6 | 968h | 48.4h | HSI | Stefan Kaliner, T-Mobile |  | Rel-7 | Gaby |  |
| 305 | 77 | Interworking between the 3GPP CS domain with BICC or ISUP as signalling protocol and external SIP-I networks | 136d? | 2006-09-22 A | 2007-03-30 | 5% | 129.2d? |  |  |  | 335d | finish no earlier than 2007-03-09 | C3 | 1088h | 54.4h | ExtSIPI | Thomas Belling, Siemens | thomas.belling@SIEMENS.COM | Rel-7 | Seung Don |  |
| 306 | 78 | **Higher Uplink performance for GERAN Evolution** | 311d? | 2006-09-08 | 2007-11-16 |  |  |  |  |  | 170d |  | GP | 12216h |  | HUGE | E. Riddington (Nokia) and S. Eriksson (Ericsson) | eddie.riddington@nokia.com, stefan.g.eriksson@ericsson.com | Rel-7 | Paolo |  |
| 307 | 78.1 | Stage 2 | 51d? | 2006-09-08 | 2006-11-17 |  |  |  |  |  | 430d | finish no earlier than 2006-11-17 | G1 | 408h |  | HUGE-Stage2 | E. Riddington (Nokia) and S. Eriksson (Ericsson) | eddie.riddington@nokia.com, stefan.g.eriksson@ericsson.com | Rel-7 | Paolo |  |
| 308 | 78.2 | Layer 1 Support | 181d? | 2006-09-08 | 2007-05-18 |  |  |  |  |  | 300d | finish no earlier than 2007-05-18 | G1 | 1448h |  | HUGE-Layer1 | E. Riddington (Nokia) and S. Eriksson (Ericsson) | eddie.riddington@nokia.com, stefan.g.eriksson@ericsson.com | Rel-7 | Paolo |  |
| 309 | 78.3 | Layer 2/3 Support | 181d? | 2006-09-08 | 2007-05-18 |  |  |  |  |  | 300d | finish no earlier than 2007-05-18 | G2 | 1448h |  | HUGE-Layer23 | E. Riddington (Nokia) and S. Eriksson (Ericsson) | eddie.riddington@nokia.com, stefan.g.eriksson@ericsson.com | Rel-7 | Gert |  |
| 310 | 78.4 | Performance requirements | 181d? | 2006-09-08 | 2007-05-18 |  |  |  |  |  | 300d | start no earlier than 2006-09-08 | G1 | 1448h |  | HUGE-Perfreq | E. Riddington (Nokia) and S. Eriksson (Ericsson) | eddie.riddington@nokia.com, stefan.g.eriksson@ericsson.com | Rel-7 | Paolo |  |
| 311 | 78.5 | MS Conformance Tests | 311d? | 2006-09-08 | 2007-11-16 |  |  |  |  |  | 170d | finish no earlier than 2007-11-16 | G3 | 2488h |  | HUGE-MStests | E. Riddington (Nokia) and S. Eriksson (Ericsson) | eddie.riddington@nokia.com, stefan.g.eriksson@ericsson.com | Rel-7 | Stoyan |  |
| 312 | 78.6 | BTS Conformance Tests | 311d? | 2006-09-08 | 2007-11-16 |  |  |  |  |  | 170d | start no earlier than 2006-09-08 | G1 | 2488h |  | HUGE-BTStests | E. Riddington (Nokia) and S. Eriksson (Ericsson) | eddie.riddington@nokia.com, stefan.g.eriksson@ericsson.com | Rel-7 | Paolo |  |
| 313 | 79 | (Small) Technical Enhancements and Improvements for Rel-7 | 490d? | 2005-05-09 | 2007-03-23 |  |  | 2005-06-06 | 2006-12-15 | 400d? | 340d | start no earlier than 2005-05-09 | All | 3920h |  | TEI7 |  |  | Rel-7 |  |  |

Notes:
- 284: Text3: 43.068, 43.069, 29.002
- 285: Text3: 43.068, 43.069
- 286: Text3: 29.002
- 288: S2#52 CREATED / Text3: 23.8de
- 289: S2#52 CREATED / Text3: 23.060
- 290: Text3: 24.008, 43.055, 43.064, 44.018, 44.060, 45.001, 45.002, 45.005, 45.008, 51.010
- 291: Text3: 43.055, 43.064
- 292: Text3: 24.008, 44.018, 44.060, 45.001, 45.002, 45.005, 45.008
- 293: Text3: 51.010
- 294: Text3: 48.001, 48.006, 43.059, 49.031
- 295: Text3: 26.234, 26.244
- 296: Text3: 32.2xy
- 297: Text3: 32.240, 32.260, 32.298, 32.299
- 298: 09/2006 SA#33 WID approved / Text3: 32.240, 32.272, 32.299, 32.298
- 299: Text3: 45.001, 45.002, 45.003, 45.005, 45.010, 43.055, 43.064, 44.060, 51.010-1, 51.021
- 300: Text3: 45.001, 45.002, 45.003, 45.005, 45.010, 43.055, 43.064, 44.060, 51.010-1, 51.021
- 301: Text3: 45.001, 45.002, 45.003, 45.005, 45.010, 43.055, 43.064, 44.060, 51.010-1, 51.021
- 302: Text3: 43.318, 44.318, 43.129, 25.306, 24.008, 44.060, 25.331, 51.010
- 303: Not to be confused with FS with same name / Text3: 23.228, 23.279
- 304: Text3: 31.101, 31.102, 31.103
- 305: Text3: new TS 29.164
- 306: Text3: 24.008, 43.055, 43.064, 44.018, 44.060, 45.001, 45.002, 45.003, 45.004, 45.005, 45.008, 45.010, 51.010, 51.021
- 307: Text3: 43.055, 43.064
- 308: Text3: 45.001, 45.002, 45.003, 45.004, 45.008
- 309: Text3: 24.008, 44.018, 44.060
- 310: Text3: 45.005
- 311: Text3: 51.010
- 312: Text3: 51.021

| ID | WBS | Task | Type | Duration | Start | Finish | Complete | Remaining | Baseline start | Baseline finish | Baseline duration | Total slack | Constraint | Resources | Work | Actual work | Text1 | Text3 | Text4 | Text5 | Text6 | Text8 | Text12 | Text7 |
| --- | --- | --- | --- | --- | --- | --- | --- | --- | --- | --- | --- | --- | --- | --- | --- | --- | --- | --- | --- | --- | --- | --- | --- | --- |
| 314 | 80 | **Deleted - PS domain and IMS support for IMS Emergency sessions** |  | 63.69d? | 2006-06-23 A | 2006-09-21 A | 100% |  | 2005-10-10 | 2006-06-23 | 185d? |  |  | S2 |  |  | IMS-EMER | 23.867, TS 23.abc, 23.060, 23.002, 23.271 | Curt Wong (Nokia) | curt.c.wong@nokia.com | Rel-7 | Maurice | SP-30 |  |
| 315 | 80.1 | Deleted - IMS aspects to support IMS Emergency sessions | milestone | 0d? | 2006-06-23 A | 2006-09-21 A | 100% |  | 2005-10-10 | 2006-06-23 | 121.31d? |  | start no earlier than 2006-06-23 | S2 |  |  |  | 23.867, TS 23.abc, 23.060, 23.002, 23.271 | Curt Wong (Nokia) | curt.c.wong@nokia.com | Rel-7 | Maurice | SP-30 | TSG |
| 316 | 80.2 | Deleted - PS domain aspects to support IMS Emergency sessions | milestone | 0d? | 2006-06-23 A | 2006-09-21 A | 100% |  | 2005-10-10 | 2006-06-23 | 121.31d? |  | start no earlier than 2006-06-23 | S2 |  |  |  | 23.867, TS 23.abc, 23.060, 23.002, 23.271 | Curt Wong (Nokia) | curt.c.wong@nokia.com | Rel-7 | Maurice | SP-30 | TSG |
| 317 | 81 | Deleted - Covered by SI - Personal Network (PN) and Personal Area Network (PAN) | milestone | 0d? | 2005-12-08 A | 2005-12-20 A | 100% |  | 2005-07-11 | 2005-12-08 | 101.2d? |  | start no earlier than 2005-12-08 | S1 |  |  | PNPAN |  | Armin Toepfer, Vodafone | armin.toepfer@vodafone.com | Rel-7 | Mike | SP-30 |  |
| 318 | 82 | Deleted - Covered by SI - Multimedia Telephony Capabilities for IMS | milestone | 0d? | 2005-12-08 A | 2005-12-20 A | 100% |  | 2005-07-11 | 2005-12-08 | 101.2d? |  | start no earlier than 2005-12-08 | S1 |  |  | MITE |  | Peter Bleckert, Ericsson | peter.bleckert @ericsson.com | Rel-7 | Mike | SP-30 |  |
| 319 | 83 | Deleted - Covered by SI - Transferring of emergency Call data | milestone | 0d? | 2005-12-08 A | 2005-12-08 A | 100% |  | 2005-07-11 | 2005-12-08 | 109d? |  | start no earlier than 2005-12-08 | S1 |  |  | eCALL |  | Steve Vardy, (Motorola S.A.S) | steven.vardy@motorola.com | Rel-7 | Mike | SP-30 |  |
| 320 | 84 | Deleted - Covered by SI - MBMS Enhancements | milestone | 0d? | 2005-12-08 A | 2005-12-08 A | 100% |  | 2005-07-11 | 2005-12-08 | 109d? |  | start no earlier than 2005-12-08 | S1 |  |  | MBMSE |  | Liu Hong, China Mobile | liuhongyfw@chinamobile.com | Rel-7 | Mike | SP-30 |  |
| 321 | 85 | Rel-7 Feasibility Studies |  | 1d? | 2000-01-03 | 2000-01-03 |  |  | 2000-01-03 | 2000-01-03 | 1d? | 2224d |  | CT;RAN;SA | 8h |  |  |  |  |  | Rel-7 |  |  |  |
| 322 | 86 | **Multimedia Telephony Capabilities for IMS** |  | 320d? | 2005-07-11 A | 2006-09-29 A | 100% |  | 2005-07-11 | 2006-09-29 | 320d? |  |  | S1 | 6089.6h | 6089.6h | MITE |  | Peter Bleckert, Ericsson | peter.bleckert @ericsson.com | Rel-7 | Mike |  |  |
| 323 | 86.1 | Study of (MITe) - IMS Multimedia Telephony Communication Enabler and supplementary services |  | 276d? | 2005-07-11 A | 2006-07-31 A | 100% |  | 2005-07-11 | 2006-07-31 | 276d? |  | start no earlier than 2005-07-11 | S1 | 2208h | 2208h |  | 22.973 | Peter Bleckert, Ericsson | peter.bleckert @ericsson.com | Rel-7 | Mike |  |  |
| 324 | 86.2 | IMS Multimedia Telephony Service |  | 173d? | 2006-02-01 A | 2006-09-29 A | 100% |  | 2006-02-01 | 2006-09-29 | 173d? |  | start no earlier than 2006-02-01 | S1 | 1384h | 1384h |  | 22.173 | Peter Bleckert, Ericsson | peter.bleckert @ericsson.com | Rel-7 | Mike |  |  |
| 325 | 87 | Study Item on IMS enhancements and optimisations for real time communication. |  | 315d? | 2005-10-10 A | 2006-12-22 | 75% | 78.75d? | 2005-10-10 | 2006-12-22 | 315d? | 405d | finish no earlier than 2006-12-22 | S2 | 2520h | 1890h | IMS-RT | 23.818 | Stephen Terrill (Ericsson) | stephen.terrill@ericsson.com | Rel-7 | Maurice |  |  |
| 326 | 88 | Behaviour of Multi system UEs |  | 480d? | 2004-06-28 A | 2006-04-28 | 90% | 48d? | 2004-06-28 | 2006-04-28 | 480d? | 575d | start no earlier than 2004-06-28 | S1 | 3840h | 3456h | BMSU | 22.936 | D Williams (QUALCOMM) | dwilliams@qualcomm.com | Rel-7 | Michael |  | TSG |
| 327 | 89 | **FS on IMS with real time services deployment** |  | 384d? | 2004-06-28 A | 2005-12-15 | 99% | 0d? | 2004-06-28 | 2005-12-15 | 384d? | 0d |  | S1 | 8672h | 6304.24h | IRTSD |  |  |  | Rel-7 | Maurice |  | TSG |
| 328 | 89.1 | Feasibility Study on Combining CS calls and IMS sessions |  | 384d? | 2004-06-28 A | 2005-12-15 A | 100% |  | 2004-06-28 | 2005-12-15 | 384d? |  | start no earlier than 2004-06-28 | S1 | 3072h | 3072h | IRTSD-CS_IMS | 22.979, 23.899 |  |  | Rel-7 | Michael |  | TSG |
| 329 | 89.2 | TR on Stage 2 (IMS services using CS bearers) |  | 316d? | 2004-06-28 A | 2005-09-12 A | 100% |  | 2004-06-28 | 2005-09-12 | 316d? |  | finish no earlier than 2005-09-12 | S2 | 2528h | 2528h | IRTSD-IMSCS | 23.899 | Mark Watson (Nortel Networks) |  | Rel-7 | Maurice |  | TSG |
| 330 | 90 | (FS on) Terminating Session handling |  | 255d? | 2006-01-09 A | 2006-12-29 | 67% | 84.15d? | 2006-01-09 | 2006-09-29 | 190d? | 400d | finish no earlier than 2006-12-29 | S2 | 2040h | 1366.8h | CSIterm |  | Osok Song (Samsung) | osok.song@samsung.com | Rel-7 | Maurice |  |  |
| 331 | 91 | FS on Performance Evaluation of the UE behaviour in high speed trains with speeds up to 350 kmph |  | 328d? | 2005-03-15 A | 2006-06-15 A | 100% |  | 2005-03-15 | 2006-06-15 | 328d? |  | finish no earlier than 2006-06-15 | R4 | 2624h | 2624h | RANFS-HSTrains |  | Mike Vogel | Mike.vogel@vodafone.com | Rel-7 | MCC_RAN |  | TSG |
| 332 | 92 | FS on Evolved UTRA and UTRAN |  | 458d? | 2004-12-15 A | 2006-09-15 A | 100% |  | 2004-12-15 | 2005-06-15 | 130d? |  | finish no earlier than 2006-09-15 | RP | 3664h | 3664h | RANFS-Evo |  | Takehiro Nakamura (NTT DoCoMo) | nakamurata@NTTDOCOMO.CO.JP | Rel-7 | MCC_RAN |  | TSG |
| 333 | 93 | **Study on Videotelephony teleservice** |  | 231d? | 2005-03-01 A | 2006-01-17 A | 100% |  | 2005-03-01 | 2006-01-17 | 231d? |  |  | S1 | 3696h | 3696h | VidTel |  | Kurt Bischinger (T-Mobile) | kurt.bischinger@t-mobile.at | Rel-7 | Michael |  | TSG |
| 334 | 93.1 | Study on Videotelephony service requirements |  | 231d? | 2005-03-01 A | 2006-01-17 A | 100% |  | 2005-03-01 | 2006-01-17 | 231d? |  | start no earlier than 2005-03-01 | S1 | 1848h | 1848h |  | 22.903 | Kurt Bischinger (T-Mobile) | kurt.bischinger@t-mobile.at | Rel-7 | Michael |  | TSG |
| 335 | 94 | **Study of Network Selection Principles** |  | 193d? | 2005-03-15 A | 2005-12-08 | 99% | 0d? | 2005-03-15 | 2005-12-08 | 193d? | 0d |  | S1 | 3088h | 2658.02h | NetSel |  | Chris Friel (O2) | chris.friel@o2.com | Rel-7 | Michael |  | TSG |
| 336 | 94.1 | Review of Network Selection Principles |  | 193d? | 2005-03-15 A | 2005-12-08 A | 100% |  | 2005-03-15 | 2005-12-08 | 193d? |  | finish no earlier than 2005-12-08 | S1 | 1544h | 1544h |  | 22.811 | Chris Friel (O2) | chris.friel@o2.com | Rel-7 | Michael |  | TSG |
| 337 | 95 | FS on Continuous connectivity for packet data users |  | 132d? | 2005-03-15 A | 2005-09-15 A | 100% |  | 2005-03-15 | 2005-09-15 | 132d? |  | finish no earlier than 2005-09-15 | R1 | 1056h | 1056h | RANFS-cont-packet |  | Joerg Gustrau | joerg.gustrau@siemens.com | Rel-7 | MCC_RAN |  | TSG |
| 338 | 96 | FS on UTRA Tower Mounted Amplifier (FDD) |  | 195d? | 2005-06-15 A | 2006-03-14 A | 100% |  | 2005-06-15 | 2006-03-14 | 195d? |  | finish no earlier than 2006-03-15 | R4 | 1560h | 1560h | RANFS-TMA |  | Klas Sjerling | Klas.Sjerling@ericsson.com | Rel-7 | MCC_RAN |  | TSG |
| 339 | 97 | Multimedia Priority Service |  | 851d? | 2003-03-28 A | 2006-06-30 A | 100% |  | 2003-03-28 | 2006-06-30 | 851d? |  | finish no earlier than 2005-12-16 | S1 | 6808h | 6808h | PRIOR-MM | 22.953 | Jim Garrahan (Telcordia) | jgarraha@telcordia.com | Rel-7 | Michael |  |  |
| 340 | 98 | Transferring of emergency Call data |  | 190d? | 2005-07-11 A | 2006-03-31 A | 100% |  | 2005-07-11 | 2006-03-31 | 190d? |  | finish no earlier than 2005-12-08 | S1 | 1520h | 1520h | eCALL | 22.967 | Steve Vardy, (Motorola S.A.S) | steven.vardy@motorola.com | Rel-7 | Mike |  |  |
| 341 | 99 | Study of a SMS Centre for MT SMS |  | 301d? | 2005-10-07 A | 2006-12-01 | 51% | 147.49d? | 2005-10-07 | 2006-06-30 | 191d? | 420d | finish no earlier than 2006-12-01 | C4 | 2408h | 1228.08h | SMS7 | 23.840 | Nick Russell, Vodafone UK | Nick.Russell@vodafone.com | Rel-7 | Kimmo |  |  |
| 342 | 100 | FS on Improvement of the Multimedia Broadcast Multicast Service (MBMS) in UTRAN |  | 262d? | 2005-12-15 A | 2006-12-15 | 70% | 78.6d? | 2005-12-15 | 2006-09-15 | 197d? | 410d | finish no earlier than 2006-12-15 | R2 | 2096h | 1467.2h | RANFS-MBMSImp |  | YoungDae Lee, LG | leego@lge.com | Rel-7 | MCC_RAN |  |  |
| 343 | 101 | FS on Performance Improvements in Small Cells using HSDPA/EDCH |  | 131d? | 2005-12-15 A | 2006-06-15 A | 100% |  | 2005-12-15 | 2006-06-15 | 131d? |  | finish no earlier than 2006-06-15 | R4 | 1048h | 1048h | SMALLCELLS |  | Marc Grant, Cingular | marc.grant@cingular.com | Rel-7 | MCC_RAN |  |  |
| 344 | 102 | FS on Further Improved Performance Requirements for UMTS/HSDPA UE (FDD) |  | 326d? | 2005-12-15 A | 2007-03-15 | 32% | 221.2d? | 2005-12-15 | 2006-12-15 | 262d? | 346d | finish no earlier than 2007-03-15 | R4 | 2608h | 838.4h | RANFS-IC |  | Marc Grant, Cingular | marc.grant@cingular.com | Rel-7 | MCC_RAN |  |  |
| 345 | 103 | FS on the TCAPsec Gateway concept |  | 96d? | 2005-10-28 A | 2006-03-10 A | 100% |  | 2005-10-28 | 2006-03-10 | 96d? |  | finish no earlier than 2006-03-10 | C4 | 768h | 768h | SEC7-TCAP | 29.800 | Ulrich Wiehe, Siemens | Ulrich.wiehe@gksag.de | Rel-7 | Kimmo |  |  |
| 346 | 104 | Study of Customised Alerting Tone (CAT) Requirements |  | 191d? | 2005-10-07 A | 2006-06-30 | 60% | 76.4d? | 2005-10-07 | 2006-06-30 | 191d? | 530d | start no earlier than 2005-10-07 | S1 | 1528h | 916.8h | CAT | 22.982 | Feng Lingjuan, China Mobile | fenglingjuan@chinamobile.com | Rel-7 | Michael |  |  |
| 347 | 105 | SI on Scope of future FDD HSPA Evolution |  | 198d? | 2006-03-15 A | 2006-12-15 | 20% | 158.4d? | 2006-03-15 | 2006-12-15 | 198d? | 410d | finish no earlier than 2006-12-15 | RP | 1584h | 316.8h | RANFS-HSPAEvo |  | Don Zelmer | don.zelmer@cingular.com | Rel-7 | MCC_RAN |  |  |

Notes:
- 314: Approved at SP#29
- 315: Approved at SP#29
- 316: Approved at SP#29
- 322: Moved from FS section Feb 06
- 325: Approved at SP#29. To be shown as feature - END Sept 06
- 326: The WID still calls it a BB, not a Feature.
- 330: S2#52: Split into Study and Specification phases.
- 339: Moved from Rel6
- 341: Study WI
- 345: Study WI / TR presented for information in CT#30
- 346: Awaiting MCC SA3 input; No input from SA3 at this time

| ID | WBS | Task | Type | Duration | Start | Finish | Complete | Remaining | Baseline start | Baseline finish | Baseline duration | Total slack | Constraint | Resources | Work | Actual work | Text1 | Text4 | Text5 | Text6 | Text7 | Text8 | Text3 | Text12 |
| --- | --- | --- | --- | --- | --- | --- | --- | --- | --- | --- | --- | --- | --- | --- | --- | --- | --- | --- | --- | --- | --- | --- | --- | --- |
| 348 | 106 | **OAM&P Studies** |  | 411d? | 2005-09-02 A | 2007-03-30 | 48% | 212.5d? | 2005-09-02 | 2006-12-15 | 336d? | 335d |  | S5 | 18288h | 9932.4h | OAM7-Study | Christian TOCHE | Christian.Toche@huawei.com | Rel-7 | TSG | Adrian |  |  |
| 349 | 106.1 | Study on IRP usage scenarios |  | 336d? | 2005-09-02 | 2006-12-15 |  |  | 2005-09-02 | 2006-12-15 | 336d? | 410d | finish no earlier than 2006-12-15 | S5 | 2688h |  | OAM7-Study | Lucent |  | Rel-7 |  |  | new TR 32.8xy | SP-32 |
| 350 | 106.2 | Study of Element Operations Systems Function (EOSF) definition |  | 336d? | 2005-09-02 A | 2006-12-15 | 45% | 184.8d? | 2005-09-02 | 2006-12-15 | 336d? | 410d | finish no earlier than 2006-12-15 | S5 | 2688h | 1209.6h | OAM7-Study | China Mobile |  | Rel-7 |  |  | new TR 32.8xy | SP-32 |
| 351 | 106.3 | Study of SOAP/HTTP IRP Solution Sets |  | 336d? | 2005-09-02 A | 2006-12-15 | 95% | 16.8d? | 2005-09-02 | 2006-12-15 | 336d? | 410d | finish no earlier than 2006-12-15 | S5 | 2688h | 2553.6h | OAM7-Study | Nortel |  | Rel-7 |  |  | new TR 32.8xy | SP-32 |
| 352 | 106.4 | Study of Itf-N Implementation Conformance Statement (ICS) template |  | 336d? | 2005-09-02 A | 2006-12-15 | 50% | 168d? | 2005-09-02 | 2006-12-15 | 336d? | 410d | finish no earlier than 2006-12-15 | S5 | 2688h | 1344h | OAM7-Study | China Mobile |  | Rel-7 |  |  | new TR 32.8xy | SP-32 |
| 353 | 106.5 | Study of IRP Information Model |  | 336d? | 2005-09-02 A | 2006-12-15 | 65% | 117.6d? | 2005-09-02 | 2006-12-15 | 336d? | 410d | finish no earlier than 2006-12-15 | S5 | 2688h | 1747.2h | OAM7-Study | Motorola |  | Rel-7 |  |  | new TR 32.8xy | SP-32 |
| 354 | 106.6 | Study on SA5 MTOSI XML Harmonization | milestone | 0d? | 2006-12-15 A | 2006-12-15 A | 100% |  | 2006-04-07 | 2006-12-15 | 181d? |  |  | S5 |  |  | OAM7-Study | Nortel |  | Rel-7 |  |  | TR 32.809 | SP-32 |
| 355 | 106.7 | **Deleted - Network Infrastructure Management** |  | 0d? | 2006-12-15 A | 2006-12-15 A | 100% |  | 2005-09-02 | 2006-12-15 | 336d? |  |  | S5 |  |  | OAM7-NIM |  |  | Rel-7 |  |  |  | SP-32 |
| 356 | 106.7.1 | Delete - was duplicated - Study on SA5 MTOSI XML Harmonization | milestone | 0d? | 2006-12-15 A | 2006-12-15 A | 100% |  | 2006-04-07 | 2006-12-15 | 181d? |  | start no earlier than 2006-12-15 | S5 |  |  | OAM7-NIM-XML | Nortel |  | Rel-7 |  |  | new TR 32.8xy | SP-30 |
| 357 | 106.8 | Study of Common Profile Storage (CPS) Framework of User Data for network services and management |  | 195d? | 2006-07-03 A | 2007-03-30 | 25% | 146.25d? |  |  |  | 335d | finish no earlier than 2007-03-30 | S5 | 1560h | 390h | OAM7-CPS | T-Mobile |  | Rel-7 |  |  | TR 32.808 |  |
| 358 | 107 | SI on AS-MRFC media server control protocol |  | 253d? | 2006-03-22 A | 2007-03-09 | 30% | 177.1d? | 2006-03-22 | 2006-09-22 | 133d? | 350d | finish no earlier than 2007-03-09 | C1 | 2024h | 607.2h | MRFC | Mark Syrett (Hewlett-Packard) |  | Rel-7 |  |  | New TR 24.880 |  |
| 359 | 108 | Study on IMS utilizing multicast bearer services |  | 193d? | 2006-03-22 A | 2006-12-15 | 25% | 144.75d? | 2006-03-22 | 2006-12-15 | 193d? | 410d | finish no earlier than 2006-12-15 | S2 | 1544h | 386h | FS-MLTICAST-IMS | Fiona Zhu (Siemens AG) |  | Rel-8 |  | Maurice | 23.847 |  |
| 360 | 109 | FS of using M2PA in 3GPP network |  | 193d? | 2006-03-22 A | 2006-12-15 | 40% | 115.8d? | 2006-03-22 | 2006-12-15 | 193d? | 410d | start no earlier than 2006-03-22 | C4 | 1544h | 617.6h | FS-M2PA |  |  |  |  | Kimmo |  |  |
| 361 | 110 | Enhancement of E2E QoS |  | 336.4d? | 2004-06-28 A | 2005-12-01 A | 100% |  | 2004-06-28 | 2005-12-01 | 336.4d? |  | finish no earlier than 2005-12-01 | S2 | 2691.2h | 2691.2h | QoS7 |  |  | Rel-7 | TSG | Maurice | 23.802 |  |
| 362 | 111 | FS WID on Bandwidth Saving at Nb Interface with IP transport |  | 261d? | 2006-03-10 A | 2007-03-09 | 19% | 211.41d? | 2006-03-10 | 2006-09-01 | 126d? | 350d | finish no earlier than 2007-03-09 | C3 | 2088h | 396.72h | BSNbIP | Thomas BELLING(Siemens) | thomas.belling@siemens.com | Rel-7 |  | Seung Don | new TR 29.814 |  |
| 363 | 112 | **3GPP System Architecture Evolution** |  | 526d? | 2004-12-03 A | 2006-12-08 | 69% | 161.42d? | 2004-12-03 | 2006-12-08 | 526d? | 415d |  | S2 | 8504h | 5894.2h | SAE |  |  | Rel-7 | TSG |  |  |  |
| 364 | 112.1 | Stage 2 Interim conclusion for RAN Work to start |  | 211d? | 2004-12-03 A | 2005-09-23 A | 100% |  | 2004-12-03 | 2005-09-23 | 211d? |  | finish no earlier than 2005-09-23 | S2 | 1688h | 1688h |  |  |  | Rel-7 |  |  | 23.882 |  |
| 365 | 112.2 | Stage 2 Feasibility study on 3GPP architectural development |  | 240d? | 2006-01-09 A | 2006-12-08 | 60% | 96d? | 2006-01-09 | 2006-12-08 | 240d? | 415d | finish no earlier than 2005-09-23 | S2 | 1920h | 1152h |  | Chris Pudney |  | Rel-7 |  | Maurice | 23.882 |  |
| 366 | 112.3 | Security study for Inter-access mobility between non 3GPP and 3GPP system |  | 86d? | 2006-02-03 A | 2006-06-02 | 20% | 68.8d? | 2006-02-03 | 2006-06-02 | 86d? | 550d | start no earlier than 2006-02-03 | S3 | 688h | 137.6h | SAE-Sec |  |  | Rel-7 |  |  | 23.882 |  |
| 367 | 112.4 | Deleted - Duplicateed with 32087 - Stage 2 Feasibility study on 3GPP architectural development | milestone | 0d? | 2006-09-27 A | 2006-09-27 A | 100% |  | 2004-12-03 | 2006-09-27 | 474d? |  | start no earlier than 2006-09-27 | S2 |  |  |  |  |  | Rel-7 |  |  | 23.882 | SP-32 |
| 368 | 113 | **FS WID on Support of (G)MSC-S - (G)MSC-S Nc Interface based on the SIP-I protocol** |  | 155d? | 2006-05-15 A | 2006-12-15 | 15% | 131.75d? |  |  |  | 410d |  | C4 | 3720h | 558h | NcSIP | David Hutton, Vodafone Group | david.hutton@vodafone.com | Rel-7 |  | Kimmo | 29.802 |  |
| 369 | 113.1 | CT4 aspects of NcSIP |  | 155d? | 2006-05-15 A | 2006-12-15 | 30% | 108.5d? |  |  |  | 410d | start no earlier than 2006-05-15 | C4 | 1240h | 372h |  |  |  | Rel-7 |  |  | 29.802 |  |
| 370 | 113.2 | CT3 aspects of NcSIP |  | 155d? | 2006-05-15 | 2006-12-15 |  |  |  |  |  | 410d | start no earlier than 2006-05-15 | C3 | 1240h |  |  | Ragnar Huslende, Ericsson | ragnar.huslende@ericsson.com | Rel-7 |  |  |  |  |
| 371 | 114 | deleted - covered by UID33027 - IMS security extensions | milestone | 0d? | 2005-12-08 A | 2005-12-08 A | 100% |  | 2005-06-28 | 2005-12-08 | 118d? |  | start no earlier than 2005-12-08 | S3 |  |  | IMS-SE | Bengt Sahlin, Ericsson | Bengt.Sahlin@ericsson.com | Rel-7 |  | Mike |  | SP-30 |
| 372 | 115 | Deleted - covered by 32108 - Study of work on an LCS architecture for I-WLAN |  | 120d? | 2006-06-26 A | 2006-12-08 | 80% | 24d? | 2006-06-26 | 2006-12-08 | 120d? | 415d | finish no earlier than 2006-12-08 | S2 | 960h | 768h |  | Donghee Shim (LG Electronics Inc.) | dhshim@lge.com ; phede@lge.com | Rel-7 |  | Maurice |  |  |

Notes:
- 361: Moved to a FS as SA32 (in line with slides)
- 362: Moved to FS at CT32 (in line with slides)
- 364: RAN work started
- 365: S2#52: Study phase created
- 368: Study WI
- 372: S2#52: Entry created

| ID | WBS | Task | Type | Duration | Start | Finish | Complete | Remaining | Baseline start | Baseline finish | Baseline duration | Total slack | Constraint | Resources | Work | Actual work | Text1 | Text6 | Text12 | Text4 | Text5 | Text7 | Text8 |
| --- | --- | --- | --- | --- | --- | --- | --- | --- | --- | --- | --- | --- | --- | --- | --- | --- | --- | --- | --- | --- | --- | --- | --- |
| 373 | 116 | **Deleted: FS on applicability of GALILEO for LCS** |  | 484d? | 2003-08-25 A | 2005-06-30 A | 100% |  | 2003-08-25 | 2005-06-30 | 484d? |  |  | S2 | 3872h | 3872h | Galileo | Rel-7 | SP-25 |  |  |  |  |
| 374 | 116.1 | Deleted - TR on Stage 2 | milestone | 0d? | 2005-06-30 A | 2005-06-30 A | 100% |  | 2005-06-30 | 2005-06-30 | 0d? |  | finish no earlier than 2005-06-30 | S2 |  |  |  | Rel-7 | SP-25 |  |  |  |  |
| 375 | 116.2 | deleted - GERAN review of the TR | milestone | 0d? | 2003-08-25 A | 2003-08-25 A | 100% |  | 2003-08-25 | 2003-08-25 | 0d? |  | finish no earlier than 2003-08-25 | GP |  |  |  | Rel-7 | SP-26 |  |  |  |  |
| 376 | 16.7 | **Deleted - IMS Local services** |  | 984d? | 2002-03-29 A | 2006-01-06 A | 100% |  | 2001-01-01 | 2005-06-08 | 1158d? |  |  | S2 | 7872h | 7872h | IMSLocal | Rel-7 | SP-28 |  |  |  |  |
| 377 | 16.7.1 | Deleted - Stage 2 | milestone | 0d | 2002-03-29 A | 2002-03-29 A | 100% |  | 2001-01-01 | 2002-03-29 | 325d |  | start no earlier than 2002-03-29 | S2 |  |  |  | Rel-7 | SP-26 |  |  |  |  |
| 378 | 117.2 | Delete - Stage 3 for IMS Local services | milestone | 0d? | 2006-01-06 A | 2006-01-06 A | 100% |  | 2004-11-10 | 2005-06-08 | 151d? |  | finish no earlier than 2006-01-06 | C1 |  |  |  | Rel-7 | SP-25 | Keith Drage, Lucent | drage@lucent.com |  |  |
| 379 | 118 | Deleted - IMS Phase 3 | milestone | 0d? | 2005-06-08 A | 2005-06-08 A | 100% |  | 2005-06-08 | 2005-06-08 | 0d? |  | finish no earlier than 2005-06-08 | S2 |  |  |  | Rel-7 | SP-25 |  |  |  |  |
| 380 | 119 | Deleted - Improvements of Radio Interface | milestone | 0d? | 2004-09-15 A | 2004-09-15 A | 100% |  | 2004-09-15 | 2004-09-15 | 0d? |  | start no earlier than 2004-09-15 | RP |  |  | RInImp | Rel-7 | SP-24 |  | Rel-7 | TSG | Cesar |
| 381 | 120 | **Deleted: Generic User Profile Phase 2** |  | 234.4d | 2004-11-12 A | 2005-10-06 A | 100% |  | 2005-10-06 | 2006-08-31 | 234.4d |  |  | C4 |  |  |  | Rel-7 | SP-27 |  |  |  | Gaby |
| 382 | 30.4 | Deleted - Stage 3 - Common objects | milestone | 0d | 2004-11-12 A | 2005-10-06 A | 100% |  | 2005-10-06 | 2006-08-31 | 0d |  | finish no earlier than 2005-10-06 | C4 |  |  |  | Rel-7 | SP-27 |  |  | TSG | Gaby |
| 383 | 121 | Delete was duplicated- Study of Customised Alerting Tone (CAT) Requirements | milestone | 0d? | 2006-06-30 A | 2006-06-30 A | 100% |  | 2005-10-07 | 2006-06-30 | 191d? |  | start no earlier than 2006-06-30 | S1 |  |  | CAT | Rel-7 | SP-31 |  |  |  |  |
| 384 | 122 | Delete - was duplicated - Facilitating Machine to Machine Communication in GSM and UMTS (M2M) | milestone | 0d? | 2006-06-16 A | 2006-06-16 A | 100% |  | 2005-11-04 | 2006-06-16 | 161d? |  | start no earlier than 2006-06-16 | S1 |  |  | M2M | Rel-7 | SP-32 | Juergen Merkel, Siemens AG |  |  | Michael |
| 385 | 123 | Deleted - FS of enhanced support of Video Telephony | milestone | 0d? | 2006-06-30 A | 2006-06-30 A | 100% |  | 2004-08-27 | 2006-06-30 | 481d? |  | start no earlier than 2006-06-30 | GP |  |  | VIDGER | Rel-7 | SP-32 | Stefan Eriksson, Ericsson | stefan.g.eriksson@ericsson.com | TSG | Paolo |
| 386 | 124 | Release 8 Features |  | 1d? | 2000-01-03 | 2000-01-03 |  |  | 2000-01-03 | 2000-01-03 | 1d? | 2224d |  | CT;RAN;SA | 8h |  |  | Rel-8 |  |  |  |  |  |
| 387 | 125 | **3G Long Term Evolution** |  | 310d? | 2006-09-25 A | 2007-11-30 | 2% | 302.73d? |  |  |  | 160d |  | RP | 10840h | 561.6h | LTE |  |  | Takehiro Nakamura (NTT DoCoMo) |  |  | MCC_RAN |
| 388 | 125.1 | 3G Long Term Evolution – Physical Layer |  | 245d? | 2006-09-25 A | 2007-08-31 | 10% | 220.5d? | 2006-03-15 | 2006-12-15 | 198d? | 225d | start no earlier than 2006-09-22 | R1 | 1960h | 196h | LTE-Phys |  |  | Sadayuki Abeta, NTT DoCoMo |  |  | MCC_RAN |
| 389 | 125.2 | 3G Long Term Evolution – Radio Interface Layer 2 and 3 Protocol Aspect |  | 245d? | 2006-09-25 | 2007-08-31 |  |  | 2006-03-15 | 2006-12-15 | 198d? | 225d | start no earlier than 2006-09-22 | R2 | 1960h |  | LTE-L23 |  |  | Benoist Sebire, Nokia |  |  | MCC_RAN |
| 390 | 125.3 | 3G Long Term Evolution – eUTRAN Interfaces |  | 245d? | 2006-09-25 | 2007-08-31 |  |  | 2006-03-15 | 2006-12-15 | 198d? | 225d | start no earlier than 2006-09-22 | R3 | 1960h |  | LTE-interfaces |  |  | Mattias Wahlqvist, Ericsson |  |  | MCC_RAN |
| 391 | 125.4 | 3G Long Term Evolution – RF Radio Transmission/Reception, System Performance Requirements and Conformance Testing |  | 310d? | 2006-09-25 | 2007-11-30 |  |  | 2006-03-15 | 2007-03-15 | 262d? | 160d | start no earlier than 2006-09-22 | R4 | 2480h |  | LTE-RF |  |  | Frank Lamprecht, Siemens |  |  | MCC_RAN |
| 392 | 126 | **3GPP System Architecture Evolution Specification** |  | 283d? | 2006-06-08 | 2007-07-09 |  |  | 2006-05-15 | 2006-12-08 | 150d? | 264d |  | S2 | 4776h |  | SAES | Rel-8 |  | Osok Song (Samsung) | osok.song@samsung.com |  | Maurice |
| 393 | 126.1 | Requirements for evolution of the 3GPP system architecture |  | 157d? | 2006-06-08 | 2007-01-12 |  |  |  |  |  | 390d | finish no earlier than 2007-01-12 | S1 | 1256h |  | AIPN-SAE | Rel-8 |  | Michael Kurz (T-Mobile International) | michael.kurz@t-mobile.at |  | Michael |
| 394 | 126.2 | Architectural aspects of SAES |  | 157d? | 2006-12-01 | 2007-07-09 |  |  |  |  |  | 264d | start no earlier than 2006-12-01 | S2 | 1256h |  | SAES-St2 | Rel-8 |  | Osok Song (Samsung) | osok.song@samsung.com |  | Maurice |
| 395 | 127 | GERAN support for GERAN - 3G Long Term Evolution interworking |  | 376d? | 2006-09-08 | 2008-02-15 |  |  |  |  |  | 105d | finish no earlier than 2008-02-15 | GP | 3008h |  | GELTE | Rel-8 |  | Han van Bussel, T-Mobile | han.van.bussel@t-mobile.de |  | Paolo |
| 396 | 128 | **Enhanced USIM Phonebook** |  | 261d? | 2006-06-22 | 2007-06-21 |  |  | 2006-01-20 | 2006-06-30 | 116d? | 276d |  | C6 | 5224h |  | eUPHBOOK | Rel-8 |  | Claus Dietze (Giesecke & Devrient) |  |  |  |
| 397 | 128.1 | Requirements for eUPHBOOK |  | 131d? | 2006-06-22 | 2006-12-21 |  |  | 2006-01-20 | 2006-06-30 | 116d? | 406d | start no earlier than 2006-06-22 | C6 | 1048h |  |  | Rel-8 |  |  |  |  |  |
| 398 | 128.2 | Implementation of eUPHBOOK |  | 261d? | 2006-06-22 | 2007-06-21 |  |  | 2006-01-20 | 2006-06-30 | 116d? | 276d | finish no earlier than 2007-06-21 | C6 | 2088h |  |  | Rel-8 |  |  |  |  |  |

Notes:
- 376: Text3: 23.228
- 377: DAB - Not yet required in SA2 as it exists in previous releases
- 380: Stage 2 description of Interim conclusion
- 381: Created at TSG#27 by A. Sultan because of the move to Rel-7 of "Common Objects".
- 382: No progress in CN4#26. This have to be moved to Rel-7. It was deleted from WID / Text3: 24.241
- 383: Awaiting MCC SA3 input
- 384: Text3: 22.868
- 385: FS CLOSED at G#28 (no input)
- 388: Text3: 36.2xy
- 389: Text3: 36.3xy
- 390: Text3: 36.4xy
- 391: Text3: 36.1xy
- 392: S2#52: Specification phase created. New WID approved SA#32 / Text3: 23.228, 23.279
- 393: Moved to SA2 at SA#32 / Text3: 22.278
- 394: S2#52: Specification phase created. New WID approved SA#32 / Text3: 23.228, 23.279
- 395: Text3: 24.008, 43.055, 43.129, 43.246, 44.018, 44.060, 45.002, 45.008, 45.010, 48.008,48.018, 51.010
- 396: Moved from Rel-7 to Rel-8 at CT#33
- 397: Text3: 21.111
- 398: Text3: 31.102

| ID | WBS | Task | Duration | Start | Finish | Complete | Remaining | Baseline start | Baseline finish | Baseline duration | Total slack | Constraint | Resources | Work | Actual work | Text1 | Text4 | Text5 | Text6 | Text8 | Text7 |
| --- | --- | --- | --- | --- | --- | --- | --- | --- | --- | --- | --- | --- | --- | --- | --- | --- | --- | --- | --- | --- | --- |
| 399 | 129 | **Enhancements for VGCS Applications** | 261d? | 2006-03-15 A | 2007-03-15 | 39% | 160.42d? | 2006-03-15 | 2006-12-06 | 191d? | 347d |  | S1 | 7664h | 2301.6h | EVA | Amar Deol, Nortel Networks | deola@nortel.com | Rel-8 | Michael |  |
| 400 | 129.1 | SA1 aspects for EVA | 191d? | 2006-03-15 A | 2006-12-06 | 90% | 19.1d? | 2006-03-15 | 2006-12-06 | 191d? | 417d | finish no earlier than 2006-12-06 | S1 | 1528h | 1375.2h |  | Amar Deol, Nortel Networks | deola@nortel.com | Rel-8 | Michael |  |
| 401 | 129.2 | C1 asptects for EVA | 204d? | 2006-06-02 A | 2007-03-15 | 10% | 183.6d? |  |  |  | 347d | finish no earlier than 2007-03-15 | C1 | 1632h | 163.2h |  | Milan Patel | milanpa@nortel.com | Rel-8 | Andrijana |  |
| 402 | 129.3 | C4 aspects for EVA | 136d? | 2006-06-02 A | 2006-12-08 | 50% | 68d? |  |  |  | 415d | finish no earlier than 2006-12-08 | C4 | 1088h | 544h |  |  |  | Rel-8 | Kimmo |  |
| 403 | 129.4 | GERAN2 Aspects of EVA | 166d? | 2006-06-30 A | 2007-02-16 | 5% | 157.7d? |  |  |  | 365d | finish no earlier than 2007-02-16 | G2 | 1328h | 66.4h | EVA-EVGCSA | Frank Billenkamp (Notrtel Networks) | frank.billenkamp@nortel.com | Rel-8 | Gert |  |
| 404 | 130 | **IMS Service Brokering enhancements** | 69d? | 2005-12-07 A | 2006-03-13 A | 100% |  | 2005-12-07 | 2006-03-13 | 69d? |  |  | S1 | 1104h | 1104h | ISB | John-Luc Bakker (Telcordia) | jbakker@telcordia.com | Rel-8 | Michael |  |
| 405 | 130.1 | Stage 1 of ISB | 69d? | 2005-12-07 A | 2006-03-13 A | 100% |  | 2005-12-07 | 2006-03-13 | 69d? |  | finish no earlier than 2006-03-13 | S1 | 552h | 552h |  | John-Luc Bakker (Telcordia) | jbakker@telcordia.com | Rel-8 | Michael |  |
| 406 | 131 | Multimedia Priority Service [in Emergency Situation] | 336d? | 2006-06-08 A | 2007-09-20 | 9% | 305.76d? | 2003-03-28 | 2006-06-30 | 851d? | 211d | finish no earlier than 2007-09-20 | S1 | 2688h | 241.92h | PRIOR-EMR | Jim Garrahan (Telcordia) | jgarraha@telcordia.com | Rel-8 | Michael |  |
| 407 | 132 | eCall Data Transfer – Requirements | 51d? | 2006-09-28 A | 2006-12-07 | 45% | 28.05d? |  |  |  | 416d | finish no earlier than 2006-12-07 | S1 | 408h | 183.6h | EData | Rhys Robinson (Airbiquity) | rrobinson@airbiquity.com | Rel-8 | Maurice |  |
| 408 | 133 | Local Charging Zone Requirements | 51d? | 2006-09-28 A | 2006-12-07 | 50% | 25.5d? |  |  |  | 416d | finish no earlier than 2006-12-07 | S1 | 408h | 204h | LCZR | Hong Liu (China Mobile) | liuhongyfw@chinamobile.com | Rel-8 | Michael |  |
| 409 | 134 | Enhancements to BS30 Bearer service for Videotelephony | 51d? | 2007-01-04 | 2007-03-15 |  |  |  |  |  | 346d | finish no earlier than 2007-03-15 | S1 | 408h |  | BS30 | Andre Jarvis (3) | andre.jarvis@three.co.uk | Rel-8 | Michael |  |
| 410 | 135 | NDS Authentication Framework Extension for TLS | 50d? | 2006-09-28 A | 2006-12-06 | 99% | 0.5d? |  |  |  | 417d | finish no earlier than 2006-09-28 | S3 | 400h | 396h | NDSAFTLS | Tiina Koskinen (Nokia) | tiina.s.koskinen@nokia.com | Rel-8 | Michael |  |
| 411 | 136 | Enhanced CELL_FACH State in FDD | 120d? | 2006-09-25 | 2007-03-09 |  |  |  |  |  | 350d | start no earlier than 2006-09-22 | R2 | 960h |  | eCFFDD | Juho Pirskanen, Nokia | juho.pirskanen@nokia.com | Rel-8 | MCC_RAN |  |
| 412 | 137 | **FBI Phase 2 - NOT YET OFFICIAL** | 349d? | 2006-06-30 A | 2007-10-31 | 8% | 319.98d? | 2003-11-05 | 2007-01-29 | 844d? | 182d |  | S2 | 10000h | 831.52h | FBI2 |  |  | Rel-8 | Maurice | TSG |
| 413 | 137.1 | **System enhancements for TISPAN Rel 2** | 349d? | 2006-06-30 A | 2007-10-31 | 8% | 319.98d? | 2006-06-01 | 2007-01-29 | 173d? | 182d |  | S2 | 7208h | 599.36h | FBI2-TISP2 |  |  | Rel-8 |  |  |
| 414 | 137.1.1 | Stage 2 of FBI for TISPAN R2 - Rel 8 | 349d? | 2006-06-30 | 2007-10-31 |  |  | 2006-06-30 | 2007-01-29 | 152d? | 182d | finish no earlier than 2007-10-31 | S2 | 2792h |  |  |  |  | Rel-8 |  |  |
| 415 | 137.1.2 | Protocol impact of FBI for TISPAN R2 | 152d? | 2006-08-16 | 2007-03-15 |  |  | 2006-06-01 | 2006-12-29 | 152d? | 346d | finish no earlier than 2007-03-15 | C1 | 1216h |  |  |  |  | Rel-8 |  |  |
| 416 | 137.1.3 | Charging harmonization for NGN between 3GPP and ATIS-TMOC | 51d? | 2006-09-28 A | 2006-12-07 | 90% | 5.1d? |  |  |  | 416d | finish no earlier than 2006-12-07 | S5 | 408h | 367.2h | FBI2-TISP2-CH | Amdocs | yishai.brown@amdocs.com | Rel-8 | Adrian |  |
| 417 | 138 | Services Alignment | 256d? | 2006-09-28 | 2007-09-20 |  |  |  |  |  | 211d | finish no earlier than 2007-09-20 | S1 | 2048h |  | ServAl | Chris Friel (O2) | chris.friel@o2.com | Rel-8 | Michael |  |
| 418 | 139 | (Small) Technical Enhancements and Improvements for Rel-8 | 400d? | 2007-01-01 | 2008-07-11 |  |  | 2005-06-06 | 2006-12-15 | 400d? | 0d | start no earlier than 2007-01-01 | All | 3200h |  | TEI8 |  |  | Rel-8 |  |  |
| 419 | 140 | Rel-8 Feasibility Studies | 1d? | 2000-01-03 | 2000-01-03 |  |  | 2000-01-03 | 2000-01-03 | 1d? | 2224d |  | CT;RAN;SA | 8h |  |  |  |  | Rel-8 |  |  |
| 420 | 141 | Facilitating Machine to Machine Communication in GSM and UMTS (M2M) | 161d? | 2005-11-04 A | 2006-06-16 | 60% | 64.4d? | 2005-11-04 | 2006-06-16 | 161d? | 540d | finish no earlier than 2006-06-16 | S1 | 1288h | 772.8h | M2M | Juergen Merkel, Siemens AG |  | Rel-8 | Michael |  |
| 421 | 142 | **All-IP Network (AIPN)** | 448d? | 2004-06-28 A | 2006-03-15 A | 100% |  | 2004-06-28 | 2006-03-15 | 448d? |  |  | S1 | 8672h | 8672h | AIPN | Chris Sachno (NTT DoCoMo) | c.masyu@nttdocomo.co.jp | Rel-8 | Michael | TSG |
| 422 | 142.1 | All-IP Network Feasibility Study | 188d? | 2004-06-28 A | 2005-03-16 A | 100% |  | 2004-06-28 | 2005-03-16 | 188d? |  | start no earlier than 2004-06-28 | S1 | 1504h | 1504h | AIPFS | Chris Sachno (NTT DoCoMo) | c.masyu@nttdocomo.co.jp | Rel-8 | Michael | TSG |
| 423 | 142.2 | Stage1 | 448d? | 2004-06-28 A | 2006-03-15 A | 100% |  | 2004-06-28 | 2006-03-15 | 448d? |  | finish no earlier than 2006-03-15 | S1 | 3584h | 3584h | AIPN | Chris Sachno (NTT DoCoMo) | c.masyu@nttdocomo.co.jp | Rel-8 | Michael | TSG |
| 424 | 143 | Study on Stage 2 aspects of IMS Service Brokering | 265d? | 2006-06-19 A | 2007-06-22 | 12% | 233.2d? |  |  |  | 275d | start no earlier than 2006-06-19 | S2 | 2120h | 254.4h | ISB_ST2_SDY | John-Luc Bakker (Telcordia) | jbakker@telcordia.com | Rel-8 | Maurice |  |
| 425 | 144 | Study of Requirements of IP-Multimedia Subsystem (IMS) Multimedia Conferencing | 205d? | 2006-06-08 A | 2007-03-21 | 10% | 184.5d? |  |  |  | 342d | finish no earlier than 2007-03-21 | S1 | 1640h | 164h | SI-IMSconf | Zheng Jianping (China Mobile ) | zhengjianping@chinamobile.com | Rel-8 | Michael |  |
| 426 | 145 | Study on support of a Public Warning System (PWS) | 205d? | 2006-06-08 A | 2007-03-21 | 10% | 184.5d? |  |  |  | 342d | start no earlier than 2006-06-08 | S1 | 1640h | 164h | PWS-SI | Frederic Thepot (NTT DoCoMo Inc.) | thepot@docomolab-euro.com | Rel-8 | Michael |  |
| 427 | 146 | Protection against SMS and MMS spam | 205d? | 2006-06-08 | 2007-03-21 |  |  |  |  |  | 342d | start no earlier than 2006-06-08 | S3 | 1640h |  | CPSMal | Eric Gauthier (Orange SA) | eric.gauthier@orange.ch | Rel-8 | Michael |  |
| 428 | 147 | Study of VCC support for Emergency Calls | 207d? | 2006-06-08 A | 2007-03-23 | 5% | 196.65d? |  |  |  | 340d | finish no earlier than 2007-03-23 | S2 | 1656h | 82.8h | FSVCCEm | Bob Beeson, Lucent |  | Rel-8 | Maurice |  |
| 429 | 148 | Study on Centralised IMS Service Control | 235d? | 2006-10-23 | 2007-09-14 |  |  | 2005-10-10 | 2006-08-31 | 234d? | 215d | finish no earlier than 2007-09-14 | S2 | 1880h |  | IMS_CSC | Andy Bennett (Lucent Technologies) | andybennett@lucent.com | Rel-8 | Maurice |  |

Notes:
- 399: Text3: 42.068
- 400: Text3: 42.068
- 401: Text3: 43.068, 44.068
- 402: CT4#32: Crs are presented and in principle agreed, waiting for the approval of stage2 / Text3: 29.002
- 403: Text3: 44.018, 48.008
- 404: Text3: 22.228
- 405: Text3: 22.228
- 406: Official name is "Multimedia Priority Service" but this is identical to UID 31041 / Text3: 22.2xx
- 407: Text3: 22.101, 22.105
- 408: Text3: 22.115
- 409: Text3: 22.002, 22.004, 22.101, 22.105, 24.008
- 410: Text3: 33.310
- 411: Text3: 25.308, 25.304, 25.306, 25.321, 25.331, 25.433, 25.435, 25.423, 25.425,
- 412: Added by MCC as a consequence of the move to Rel8 of TISPAN Rel-2 impacts on 3GPP
- 416: 09/2006 SA#33 WID approved / Text3: 32.297
- 417: Text3: 22.9xx
- 420: Text3: 22.868
- 421: Text3: 22.978
- 422: Text3: 22.978
- 423: Text3: 22.258
- 424: Study approved SA#32 / Text3: 23.810
- 425: Text3: 22.948
- 426: Text3: 22.968
- 427: Formerly called "Consumer protection against spam and malware" / Text3: 33.9xx
- 428: Text3: 23.8xx
- 429: Approved at SP#33 / Text3: 23.9de

| ID | WBS | Task | Duration | Start | Finish | Total slack | Constraint | Resources | Work | Text1 | Text3 | Text4 | Text5 | Text6 | Text8 |
| --- | --- | --- | --- | --- | --- | --- | --- | --- | --- | --- | --- | --- | --- | --- | --- |
| 430 | 149 | **Study on Dynamically reconfiguring a FDD UE receiver to reduce power consumption when desired Quality of Service is met** | 120d? | 2006-09-25 | 2007-03-09 | 350d |  | RP | 2880h | FSUEPow | 25.xxx | Chris Callender, Nokia | Chris.callender@nokia.com | Rel-8 | MCC_RAN |
| 431 | 149.1 | RAN2 aspects of FSUEPow | 120d? | 2006-09-25 | 2007-03-09 | 350d | start no earlier than 2006-09-22 | R2 | 960h | FSUEPow |  | Tiina Koskinen (Nokia) | tiina.s.koskinen@nokia.com | Rel-8 | MCC_RAN |
| 432 | 149.2 | RAN4 aspects of FSUEPow | 120d? | 2006-09-25 | 2007-03-09 | 350d | start no earlier than 2006-09-22 | R4 | 960h | FSUEPow |  | Tiina Koskinen (Nokia) | tiina.s.koskinen@nokia.com | Rel-8 | MCC_RAN |
| 433 | 150 | Study on Paging Permission with Access Control (PPAC) | 256d? | 2006-09-28 | 2007-09-20 | 211d | finish no earlier than 2007-09-20 | S1 | 2048h | PPAC | 22.9xx | Katsuhiro Noguchi (NTT DoCoMo Inc.) | noguchi@nttdocomo.co.jp | Rel-8 | Michael |
